# HUAURA III-2 - CUENCA ALTA

Schedule from Primavera P6, 2024-06-13 to 2025-10-05, data date 2024-06-13, costs in USD.
Must finish by 2025-10-06

## Calendars

- Huara III-2: Mon-Sun 08:00-16:00.

## Resources

| Resource | Group | Unit | Rate |
| --- | --- | --- | --- |
| Excavator | labor |  | 70 |
| HH | labor |  |  |
| MONEDA | material |  | 1 |
| Grava para drenaje | material |  |  |
| Relleno mejorado con Cemento | material |  |  |
| Geotextil | material |  |  |
| Roca | material | m3 |  |
| Cerco | material |  |  |
| Relleno estructural | material |  |  |
| CONCRETO PREMEZCLADO F'C=100 kg/cm2 CON CEMENTO T-I | material |  |  |
| CONCRETO PREMEZCLADO F'C=280 kg/cm2 CON CEMENTO T-I | material |  |  |
| PIEDRA CHANCADA | material |  |  |
| ARENA GRUESA | material |  |  |
| CEMENTO PORTLAND TIPO I (42.5 kg) | material |  |  |
| MADERA TORNILLO | material | und |  |
| acero | material |  |  |
| PINTURA ASFALTICA | material |  |  |
| Petroleo | material | gln |  |

## Schedule

| ID | WBS | Activity | Type | Duration | Start | Finish | Predecessors | Total float | Free float | Resources | Cost |
| --- | --- | --- | --- | --- | --- | --- | --- | --- | --- | --- | --- |
|  | 3 | **HITOS** |  |  | 2024-06-13 | 2025-10-05 |  |  |  |  |  |
| A4720 |  | Inicio de Obra-Acceso al sitio | milestone | 0d | 2024-06-13 | 2024-06-13 |  | 0d |  |  |  |
| A4730 |  | Iinicio de Obras Preliminares | milestone | 0d | 2024-07-04 | 2024-07-04 | A4720 FS+21d | 0d |  |  |  |
| A4740 |  | Inicio de Obras - Diques Paquete 4 | milestone | 0d | 2024-07-27 | 2024-07-27 | A4730 FS+23d | 0d |  |  |  |
| A4750 |  | Fin de Obras - Diques Paquete 4 | milestone | 0d | 2025-09-21 | 2025-09-21 | A7830 FF, A7840 FF, A7860 FF, A7870 FF, A7310 FF, A7330 FF, A7470 FF, A7490 FF, A7510 FF, A7530 FF, A7550 FF, A7590 FF, A7610 FF, A7670 FF, A7690 FF, A7710 FF, A7730 FF, A7770 FF, A7790 FF, A7390 FF, A7410 FF, A7430 FF, A7942 FF, A7961 FF, A2420 FF, A7900 FF | 14d |  |  |  |
| A4780 |  | Culminación de Obras | milestone | 0d | 2025-10-05 | 2025-10-05 | A5380 FF, A5420 FF, A5440 FF, A5520 FF, A5570 FF, A7880 FF, A8150 FF, A8070 FF, A8090 FF, A8020 FF, A8010 FF, A7962 FF, A8270 FF, A2380 FF, A7010 FF, A7570 FF, A5470 FF, A7650 FF, A7370 FF, A7750 FF | 0d |  |  |  |
|  | 1 | **OBRAS PROVISIONALES** |  |  | 2024-06-20 | 2025-10-05 |  |  |  |  |  |
| A5380 |  | Campamento provisional de obra |  | 30d | 2024-07-04 | 2024-08-02 | A4730 SS | 429d |  | HH [240 h] | 454,113.93 |
| A5420 |  | Mantenimiento de caminos de acceso |  | 444d | 2024-07-05 | 2025-09-21 | A4730 SS, A5390 | 14d |  | HH [3592 h]; Petroleo [791935 gln] | 571,469.51 |
|  | 1 | **Obras Provisionales 2024** |  |  | 2024-06-20 | 2025-01-15 |  |  |  |  |  |
| A5390 |  | Movilizacion de maquinaria pesada |  | 15d | 2024-06-20 | 2024-07-04 | A4720 SS+7d | 14d | 0d | HH [120 h] |  |
| A7890 |  | Desviación y encauzamiento del río |  | 180d | 2024-07-05 | 2024-12-31 | A4730 SS, A5390 | 263d | 0d | HH [3592 h] |  |
| A5410 |  | Limpieza manual de material vegetal y de residuos |  | 175d | 2024-07-10 | 2024-12-31 | A4730 SS, A5390 FS+5d | 278d | 0d | HH [1328 h] |  |
| A5430 |  | Habilitacion de plataformas |  | 20d | 2024-07-13 | 2024-08-01 | A5390 FS+8d, A4730 SS | 278d | 0d | HH [160 h] |  |
| A5400 |  | Mejoramiento y habilitación de caminos de acceso |  | 168d | 2024-07-17 | 2024-12-31 | A4730 SS, A5390, A5430 SS+4d | 278d | 0d | HH [1152 h] |  |
| A5520 |  | Desbroce en areas auxiliares |  | 30d | 2024-07-17 | 2024-08-15 | A5400 SS, A4730 SS | 416d |  | HH [240 h] |  |
| A5570 |  | Desmovilizacion de maquinaria pesada |  | 15d | 2025-01-01 | 2025-01-15 | A6200, A7890 | 263d |  | HH [120 h] |  |
|  | 2 | **Obras Provisionales 2025** |  |  | 2024-07-15 | 2025-10-05 |  |  |  |  |  |
| A5440 |  | Cruces de rio |  | 20d | 2024-07-15 | 2024-08-03 | A5410 SS+5d, A4730 SS | 428d |  | HH [96 h] |  |
| A7820 |  | Movilizacion de maquinaria pesada |  | 15d | 2025-04-16 | 2025-04-30 | A5370 SS+105d | 14d | 0d | HH [120 h] |  |
| A7900 |  | Desviación y encauzamiento del río |  | 159d | 2025-04-16 | 2025-09-21 | A5370 SS+105d | 14d | 0d | HH [3592 h] |  |
| A7830 |  | Mejoramiento y habilitación de caminos de acceso |  | 157d | 2025-04-18 | 2025-09-21 | A7820 SS, A7850 SS | 14d | 0d | HH [1168 h] |  |
| A7850 |  | Habilitacion de plataformas |  | 20d | 2025-04-18 | 2025-05-07 | A7820 SS+2d | 14d | 0d | HH [160 h] |  |
| A7860 |  | Cruces de rio |  | 13d | 2025-04-18 | 2025-04-30 | A7820 SS+2d | 158d | 144d | HH [96 h] |  |
| A7840 |  | Limpieza manual de material vegetal y de residuos |  | 154d | 2025-04-21 | 2025-09-21 | A7820 SS+5d | 14d | 0d | HH [1184 h] |  |
| A7870 |  | Desbroce en areas auxiliares |  | 30d | 2025-04-21 | 2025-05-20 | A7820 SS+5d | 138d | 124d | HH [240 h] |  |
| A7880 |  | Desmovilizacion de maquinaria pesada |  | 14d | 2025-09-22 | 2025-10-05 | A4700 SS, A7550, A7630 FF+6d, A7790 FF+5d, A7690 FF+5d | 0d |  | HH [144 h] |  |

| ID | WBS | Activity | Type | Duration | Start | Finish | Predecessors | Total float | Free float | Resources | Cost |
| --- | --- | --- | --- | --- | --- | --- | --- | --- | --- | --- | --- |
|  | 2 | **DIQUES Y MUROS** |  |  | 2024-06-13 | 2025-09-21 |  |  |  |  |  |
|  | 29 | **CONSTRUCCION DIQUES 2024** |  |  | 2024-06-13 | 2025-01-31 |  |  |  |  |  |
| A1111 |  | Permisos y Habilitación de Canteras |  | 49d | 2024-06-13 | 2024-07-31 | A4720 SS | 0d |  |  |  |
| A7941 |  | Produccion de roca en cantera Cumbre |  | 153d | 2024-08-01 | 2024-12-31 | A4720 SS+5d, A1111 | 7d | 0d |  |  |
| A7949 |  | Produccion de roca en cantera Tres Montones para 2024 |  | 153d | 2024-08-01 | 2024-12-31 | A1111 | 0d |  |  |  |
| A7942 |  | Suministro de Roca Cantera Cumbre |  | 128d | 2024-08-26 | 2024-12-31 | A7941 SS+25d | 7d | 0d |  |  |
| A7951 |  | Suministro de Roca de cantera Tres Montones para 2024 |  | 128d | 2024-08-26 | 2024-12-31 | A7949 SS+25d | 0d |  |  |  |
| A8260 |  | Produccion de roca en cantera Tres Montones para 2025 |  | 31d | 2025-01-01 | 2025-01-31 | A7949 | 99d | 89d |  |  |
|  | 6 | **SOLUCION DE INTERFERENCIAS** |  |  | 2024-07-13 | 2024-11-13 |  |  |  |  |  |
| A8000 |  | Solucion de interferencias Dique D-06-DI (INT-01 INT-0 2 INT-03 - Tipo tubo) |  | 15d | 2024-07-13 | 2024-07-27 | A4730 SS+9d | 14d | 0d |  |  |
| A8030 |  | Solucion de interferencias Dique D-06-DI (CAN01 D-06-DI-CAN02 D-06-DI-CAN03- Tipo canal) |  | 15d | 2024-07-28 | 2024-08-11 | A8000 | 28d |  |  |  |
| A8150 |  | Solucion de interferencias Dique I-11-PT (INT 01 INT 02 INT 03- Tipo tubo) |  | 30d | 2024-07-28 | 2024-08-26 | A2430 SS+1d | 405d |  |  |  |
| A8040 |  | Solucion de interferencias Dique D-04-PT (INT 01 INT 01 TL-01 - Tipo tubo) |  | 20d | 2024-08-04 | 2024-08-23 | A1420 FS+4d | 51d | 46d |  |  |
| A8050 |  | Solucion de interferencias Dique D-04-PT (CAN01 D-04-PT-CAN02 - Tipo canal) |  | 20d | 2024-08-14 | 2024-09-02 | A1420 FS+14d | 120d | 66d |  |  |
| A8080 |  | Solucion de interferencias Dique I-15-1-DI (INT 01 INT02 INT03 TL01 - Tipo tubo) |  | 15d | 2024-10-08 | 2024-10-22 | A1540 | 20d | 0d |  |  |
| A8140 |  | Solucion de interferencias en Dique I-08-DI |  | 33d | 2024-10-12 | 2024-11-13 | A2810 | 21d | 13d |  |  |
| A8090 |  | Solucion de interferencias Dique I-15-1-DI (CAN01 - Tipo canal) |  | 10d | 2024-10-18 | 2024-10-27 | A1540, A8080 SS+10d | 343d |  |  |  |
|  | 1 | **D-06-DI** |  |  | 2024-07-27 | 2024-10-12 |  |  |  |  |  |
| A7300 |  | Inicio D-06-DI - 58+217.72 - Entrega de terreno liberado | milestone | 0d | 2024-07-27 | 2024-07-27 | A4740 SS, A8000 SS | 0d |  |  |  |
| A7310 |  | Fin D-06-DI - 58+217.72 - Entrega de terreno liberado | milestone | 0d | 2024-10-12 | 2024-10-12 | A5780 FF, A1230 FF, A5800 FF | 358d | 344d |  |  |
|  | 1 | **DIQUE** |  |  | 2024-07-27 | 2024-10-12 |  |  |  |  |  |
|  | 1 | **Excavaciones** |  |  | 2024-07-27 | 2024-09-21 |  |  |  |  |  |
| A1000 |  | Desbroce |  | 4d | 2024-07-27 | 2024-07-30 | A7300 SS | 0d |  | Excavator [32 h]; HH [32 h] | 2,240 |
| A1010 |  | Excavacion de cimentacion |  | 33d | 2024-07-27 | 2024-08-28 | A1000 SS | 0d |  | Excavator [256 h]; HH [264 h] | 17,956.71 |
| A1020 |  | Perfilado y conformación de plataforma de fundación |  | 13d | 2024-08-15 | 2024-08-27 | A1010 SS+19d | 1d |  | HH [104 h] |  |
| A1030 |  | Excavacion de uña |  | 24d | 2024-08-29 | 2024-09-21 | A1010, A1020 | 0d |  | Excavator [184 h]; HH [192 h] | 12,880 |

| ID | WBS | Activity | Type | Duration | Start | Finish | Predecessors | Total float | Free float | Resources | Cost |
| --- | --- | --- | --- | --- | --- | --- | --- | --- | --- | --- | --- |
|  | 2 | **Rellenos** |  |  | 2024-08-07 | 2024-09-16 |  |  |  |  |  |
| A1040 |  | Relleno con material granular (incluye extracción de material, zarandeo y / combinación de material) |  | 33d | 2024-08-07 | 2024-09-08 | A1010 SS+11d | 0d |  | HH [264 h]; MONEDA [14826.5] | 14,826.53 |
| A1210 |  | Perfilado de talud del dique |  | 17d | 2024-08-23 | 2024-09-08 | A1040 SS+16d | 0d |  | HH [136 h] |  |
| A1220 |  | Grava para drenaje |  | 13d | 2024-08-27 | 2024-09-08 | A1040 SS+20d | 0d |  | HH [104 h]; Grava para drenaje [810.46] |  |
| A1230 |  | Relleno mejorado con cemento |  | 8d | 2024-09-09 | 2024-09-16 | A1040 | 384d | 26d | HH [64 h]; Relleno mejorado con Cemento [639] |  |
|  | 3 | **Geotextil** |  |  | 2024-08-17 | 2024-09-09 |  |  |  |  |  |
| A1250 |  | Zanja de anclaje |  | 6d | 2024-08-17 | 2024-08-22 | A1040 SS+10d | 32d | 0d | HH [48 h] |  |
| A1240 |  | Instalación de geotextil 400 gr/m2 |  | 23d | 2024-08-18 | 2024-09-09 | A1250 SS+1d | 32d | 0d | HH [184 h]; Geotextil [13483] |  |
|  | 4 | **Colocación de roca** |  |  | 2024-08-26 | 2024-10-02 |  |  |  |  |  |
| A1260 |  | Colocación de roca en uña |  | 14d | 2024-08-26 | 2024-09-08 | A1010 SS+30d, A7951 SS | 0d |  | Excavator [104 h]; HH [104 h]; Roca [9352.25 m3] | 7,280 |
| A1270 |  | Colocación de roca en talud |  | 24d | 2024-09-09 | 2024-10-02 | A1260, A1210, A1220, A8000, A8030, A1030 SS+11d | 0d |  | Excavator [184 h]; HH [184 h]; Roca [7644.31 m3] | 12,880 |
|  | 5 | **Transporte** |  |  | 2024-07-27 | 2024-10-12 |  |  |  |  |  |
| A5750 |  | Transporte de material orgánico (a dmo) |  | 4d | 2024-07-27 | 2024-07-30 | A1000 SS | 379d | 0d | HH [40 h] |  |
| A5760 |  | Transporte de material excedente |  | 57d | 2024-07-27 | 2024-09-21 | A1010 SS, A5750 SS | 379d | 11d | HH [456 h] |  |
| A5770 |  | Transporte de material de prestamo (afirmado) |  | 33d | 2024-08-07 | 2024-09-08 | A1040 SS, A5760 SS | 392d | 0d | HH [328 h] |  |
| A5790 |  | Transporte de material de préstamo cantera de rio (cuerpo de terraplén) |  | 33d | 2024-08-07 | 2024-09-08 | A1040 SS, A5770 SS | 392d | 10d | HH [328 h] |  |
| A5800 |  | Transporte de material seleccionado para zanja |  | 6d | 2024-08-17 | 2024-08-22 | A1250 SS, A5790 SS | 409d | 51d | HH [48 h] |  |
| A5780 |  | Transporte de roca |  | 38d | 2024-09-05 | 2024-10-12 | A1240 SS+18d | 32d | 0d | HH [296 h] |  |
|  | 4 | **I-15-1-DI** |  |  | 2024-10-03 | 2024-12-31 |  |  |  |  |  |
| A7320 |  | Inicio I-15-1-DI-67+628.33 - Entrega de terreno liberado | milestone | 0d | 2024-10-03 | 2024-10-03 | A1270 | 0d |  |  |  |
| A7330 |  | Fin I-15-1-DI-67+628.33 - Entrega de terreno liberado | milestone | 0d | 2024-12-31 | 2024-12-31 | A1670 FF, A1620 FF, A5820 FF, A5840 FF | 0d |  |  |  |
|  | 1 | **DIQUE** |  |  | 2024-10-03 | 2024-12-31 |  |  |  |  |  |
|  | 1 | **Excavaciones** |  |  | 2024-10-03 | 2024-11-20 |  |  |  |  |  |
| A1540 |  | Desbroce |  | 5d | 2024-10-03 | 2024-10-07 | A7320 SS | 0d |  | Excavator [40 h]; HH [40 h] | 2,800 |
| A1550 |  | Excavacion de cimentación |  | 24d | 2024-10-03 | 2024-10-26 | A1540 SS | 0d |  | Excavator [184 h]; HH [184 h] | 12,880 |
| A1560 |  | Perfilado y conformación de plataforma de fundación |  | 17d | 2024-10-09 | 2024-10-25 | A1550 SS+6d | 1d |  | HH [136 h] |  |
| A1570 |  | Excavacion de uña |  | 25d | 2024-10-27 | 2024-11-20 | A1550, A1560 | 0d |  | Excavator [168 h]; HH [168 h] | 11,760 |

| ID | WBS | Activity | Type | Duration | Start | Finish | Predecessors | Total float | Free float | Resources | Cost |
| --- | --- | --- | --- | --- | --- | --- | --- | --- | --- | --- | --- |
|  | 2 | **Rellenos** |  |  | 2024-10-13 | 2024-11-01 |  |  |  |  |  |
| A1580 |  | Relleno con material granular (incluye extracción de material, zarandeo y / combinación de material) |  | 15d | 2024-10-13 | 2024-10-27 | A1550 SS+10d | 10d | 0d | HH [120 h]; MONEDA [13880.9] | 13,880.91 |
| A1590 |  | Perfilado de talud del dique |  | 14d | 2024-10-16 | 2024-10-29 | A1580 SS+3d | 19d | 9d | HH [104 h] |  |
| A1610 |  | Relleno mejorado con cemento |  | 12d | 2024-10-18 | 2024-10-29 | A1580 SS+5d | 10d | 0d | HH [96 h]; Relleno mejorado con Cemento [999] |  |
| A1600 |  | Grava para drenaje |  | 5d | 2024-10-25 | 2024-10-29 | A1580 SS+12d, A1590 SS | 10d | 0d | HH [40 h]; Grava para drenaje [331.81] |  |
| A1620 |  | Relleno estructural |  | 3d | 2024-10-30 | 2024-11-01 | A1580 FS+1d, A1610, A1600 | 10d |  | HH [16 h]; Relleno estructural [215] |  |
|  | 3 | **Geotextil** |  |  | 2024-10-20 | 2024-11-19 |  |  |  |  |  |
| A1640 |  | Zanja de anclaje |  | 11d | 2024-10-20 | 2024-10-30 | A1580 SS+7d | 12d | 0d | HH [80 h] |  |
| A1630 |  | Instalación de geotextil 400 gr/m2 |  | 20d | 2024-10-31 | 2024-11-19 | A1640 | 12d |  | HH [160 h]; Geotextil [21616] |  |
|  | 4 | **Colocacion de Roca** |  |  | 2024-10-06 | 2024-12-31 |  |  |  |  |  |
| A1650 |  | Colocación de roca en uña |  | 37d | 2024-10-06 | 2024-11-11 | A1550 SS+3d, A7951 SS | 0d |  | Excavator [288 h]; HH [288 h]; Roca [16805.8 m3] | 20,160 |
| A1660 |  | Colocación de roca en talud |  | 48d | 2024-11-12 | 2024-12-29 | A1650, A1570 SS+16d, A1630 SS, A8080, A1620 | 0d |  | Excavator [376 h]; HH [376 h]; Roca [14772.1 m3] | 26,320 |
| A1670 |  | Colocación de roca en corona |  | 2d | 2024-12-30 | 2024-12-31 | A1660 | 0d |  | Excavator [8 h]; HH [8 h]; Roca [66 m3] | 560 |
|  | 5 | **Transporte** |  |  | 2024-10-03 | 2024-12-30 |  |  |  |  |  |
| A5810 |  | Transporte de material orgánico (a dmo) |  | 5d | 2024-10-03 | 2024-10-07 | A1540 SS | 41d | 0d | HH [40 h] |  |
| A5840 |  | Transporte de roca |  | 86d | 2024-10-06 | 2024-12-30 | A1650 SS, A5780 SS | 1d |  | HH [672 h] |  |
| A5820 |  | Transporte de material excedente |  | 44d | 2024-10-08 | 2024-11-20 | A1550 SS, A5810, A5860 FF | 41d |  | HH [376 h] |  |
| A5830 |  | Transporte de material de prestamo (afirmado) |  | 15d | 2024-10-13 | 2024-10-27 | A1580 SS | 70d | 0d | HH [152 h] |  |
| A5850 |  | Transporte de material de préstamo cantera de rio (cuerpo de terraplén) |  | 15d | 2024-10-13 | 2024-10-27 | A1580 SS, A5830 SS | 70d | 7d | HH [152 h] |  |
| A5860 |  | Transporte de material seleccionado para zanja |  | 10d | 2024-10-20 | 2024-10-29 | A1640 SS, A5850 SS | 63d | 22d | HH [80 h] |  |
|  | 3 | **D-04-PT** |  |  | 2024-07-27 | 2024-11-07 |  |  |  |  |  |
| A7380 |  | Inicio D-04-PT-61+080.84 - Entrega de terreno liberado | milestone | 0d | 2024-07-27 | 2024-07-27 | A4740 SS | 5d | 0d |  |  |
| A7390 |  | Fin D-04-PT-61+080.84 - Entrega de terreno liberado | milestone | 0d | 2024-11-07 | 2024-11-07 | A1530 FF, A1490 FF, A6000 FF, A6020 FF, A8050 FF | 54d |  |  |  |
|  | 1 | **DIQUE** |  |  | 2024-07-27 | 2024-11-07 |  |  |  |  |  |
|  | 1 | **Excavaciones** |  |  | 2024-07-27 | 2024-09-20 |  |  |  |  |  |
| A1420 |  | Desbroce |  | 4d | 2024-07-27 | 2024-07-30 | A7380 SS | 5d | 0d | Excavator [32 h]; HH [32 h] | 2,240 |
| A1430 |  | Excavacion de cimentación |  | 43d | 2024-07-27 | 2024-09-07 | A1420 SS | 5d | 0d | Excavator [344 h]; HH [344 h] | 24,080 |
| A1440 |  | Perfilado y conformación de plataforma de fundación |  | 31d | 2024-08-08 | 2024-09-07 | A1430 SS+12d | 36d | 0d | HH [248 h] |  |
| A1450 |  | Excavacion de uña |  | 13d | 2024-09-08 | 2024-09-20 | A1430, A1440 | 36d | 31d | Excavator [104 h]; HH [104 h] | 7,280 |

| ID | WBS | Activity | Type | Duration | Start | Finish | Predecessors | Total float | Free float | Resources | Cost |
| --- | --- | --- | --- | --- | --- | --- | --- | --- | --- | --- | --- |
|  | 2 | **Rellenos** |  |  | 2024-08-12 | 2024-08-26 |  |  |  |  |  |
| A1460 |  | Relleno con material granular (incluye extracción de material, zarandeo y / combinación de material) |  | 4d | 2024-08-12 | 2024-08-15 | A1430 SS+16d | 56d | 0d | HH [24 h]; MONEDA [1783.6] | 1,783.6 |
| A1470 |  | Perfilado de talud del dique |  | 4d | 2024-08-16 | 2024-08-19 | A1460 | 127d | 0d | HH [32 h] |  |
| A1480 |  | Relleno con material seleccionado (incluye extracción de material, / zarandeo y combinación de material) en sobreex |  | 11d | 2024-08-16 | 2024-08-26 | A1460, A1470 SS | 127d | 0d | HH [80 h]; Cerco [1700.2] |  |
| A1490 |  | Relleno mejorado con cemento |  | 9d | 2024-08-18 | 2024-08-26 | A1460 FS+2d, A1480 SS+2d | 127d | 73d | HH [64 h]; Relleno mejorado con Cemento [703] |  |
|  | 3 | **Geotextil** |  |  | 2024-08-12 | 2024-08-30 |  |  |  |  |  |
| A1510 |  | Zanja de anclaje |  | 7d | 2024-08-12 | 2024-08-18 | A1460 SS | 56d | 0d | HH [48 h] |  |
| A1500 |  | Instalación de geotextil 400 gr/m2 |  | 12d | 2024-08-19 | 2024-08-30 | A1510 | 56d | 51d | HH [96 h]; Geotextil [14015] |  |
|  | 4 | **Colocacion de Roca** |  |  | 2024-08-26 | 2024-11-07 |  |  |  |  |  |
| A1520 |  | Colocación de roca en uña |  | 44d | 2024-08-26 | 2024-10-08 | A1430 SS+30d, A7951 SS | 5d | 0d | Excavator [176 h]; HH [176 h]; Roca [10100.2 m3] | 12,320 |
| A1530 |  | Colocación de roca en talud |  | 30d | 2024-10-09 | 2024-11-07 | A1520, A1500 SS, A1450 SS, A8040 | 5d | 0d | Excavator [184 h]; HH [184 h]; Roca [7140.01 m3] | 12,880 |
|  | 5 | **Transporte** |  |  | 2024-07-27 | 2024-10-09 |  |  |  |  |  |
| A5990 |  | Transporte de material orgánico (a dmo) |  | 4d | 2024-07-27 | 2024-07-30 | A1420 SS | 102d | 0d | HH [32 h] |  |
| A6000 |  | Transporte de material excedente |  | 56d | 2024-07-27 | 2024-09-20 | A1430 SS, A5990 SS, A6010 FF | 102d | 48d | HH [448 h] |  |
| A6010 |  | Transporte de material de prestamo (afirmado) |  | 4d | 2024-08-12 | 2024-08-15 | A1460 SS, A6030 SS | 138d | 36d | HH [32 h] |  |
| A6030 |  | Transporte de material de préstamo cantera de rio (cuerpo de terraplén) |  | 4d | 2024-08-12 | 2024-08-15 | A1460 SS, A6040 SS | 138d | 0d | HH [40 h] |  |
| A6040 |  | Transporte de material seleccionado para zanja |  | 7d | 2024-08-12 | 2024-08-18 | A1510 SS | 138d | 0d | HH [24 h] |  |
| A6020 |  | Transporte de roca |  | 45d | 2024-08-26 | 2024-10-09 | A1520 SS | 83d | 29d | HH [360 h] |  |
|  | 5 | **I-15-2-DI - Muro** |  |  | 2024-11-08 | 2024-12-26 |  |  |  |  |  |
| A7340 |  | Inicio I-15-2-DI-68+726.84 - Entrega de terreno liberado | milestone | 0d | 2024-11-08 | 2024-11-08 | A1530 | 5d | 0d |  |  |
| A7350 |  | Fin I-15-2-DI-68+726.84 - Entrega de terreno liberado | milestone | 0d | 2024-12-26 | 2024-12-26 | A1700 FF, A1790 FF, A1810 FF, A5900 FF | 5d |  |  |  |
|  | 1 | **DIQUE** |  |  | 2024-11-08 | 2024-12-26 |  |  |  |  |  |
|  | 1 | **Excavaciones** |  |  | 2024-11-08 | 2024-11-25 |  |  |  |  |  |
| A1680 |  | Desbroce |  | 1d | 2024-11-08 | 2024-11-08 | A7340 SS | 15d | 0d | Excavator [8 h]; HH [8 h] | 560 |
| A1690 |  | Excavacion de cimentación |  | 18d | 2024-11-08 | 2024-11-25 | A1680 SS | 15d | 0d | Excavator [144 h]; HH [144 h] | 10,080 |

| ID | WBS | Activity | Type | Duration | Start | Finish | Predecessors | Total float | Free float | Resources | Cost |
| --- | --- | --- | --- | --- | --- | --- | --- | --- | --- | --- | --- |
|  | 4 | **Colocacion de Roca** |  |  | 2024-12-06 | 2024-12-14 |  |  |  |  |  |
| A1710 |  | Colocación de roca en uña |  | 7d | 2024-12-06 | 2024-12-12 | A1750, A1800 FS+7d, A1690, A7951 SS | 5d | 0d | Excavator [56 h]; HH [56 h]; Roca [1780.89 m3] | 3,920 |
| A1720 |  | Colocación de roca en talud |  | 2d | 2024-12-13 | 2024-12-14 | A1710 | 5d | 0d | Excavator [8 h]; HH [8 h]; Roca [267.77 m3] | 560 |
|  | 2 | **Rellenos** |  |  | 2024-12-15 | 2024-12-26 |  |  |  |  |  |
| A1700 |  | Relleno estructural |  | 12d | 2024-12-15 | 2024-12-26 | A1830, A1720 | 5d | 0d | HH [104 h]; Relleno estructural [4040] |  |
|  | 5 | **Transporte** |  |  | 2024-11-08 | 2024-12-14 |  |  |  |  |  |
| A5870 |  | Transporte de material orgánico (a dmo) |  | 1d | 2024-11-08 | 2024-11-08 | A1680 SS | 27d | 0d | HH [16 h] |  |
| A5880 |  | Transporte de material excedente |  | 18d | 2024-11-08 | 2024-11-25 | A1690 SS, A5870 SS | 27d | 0d | HH [144 h] |  |
| A5890 |  | Transporte de material de prestamo (afirmado) |  | 8d | 2024-11-18 | 2024-11-25 | A5880 SS+10d | 27d | 10d | HH [64 h] |  |
| A5900 |  | Transporte de roca |  | 9d | 2024-12-06 | 2024-12-14 | A1710 SS, A5880, A5890 | 17d | 12d | HH [64 h] |  |
|  | 3 | **MURO** |  |  | 2024-11-08 | 2024-12-08 |  |  |  |  |  |
| A1730 |  | Concreto de nivelacion (f'c=100 kg/cm2) |  | 8d | 2024-11-08 | 2024-11-15 | A7340 SS | 5d | 0d | HH [48 h]; CONCRETO PREMEZCLADO F'C=100 kg/cm2 CON CEMENTO T-I [108] |  |
| A1760 |  | Encofrado y desencofrado caravista |  | 17d | 2024-11-08 | 2024-11-24 | A1770 SS | 19d | 3d | HH [136 h] |  |
| A1770 |  | Encofrado y desencofrado cara oculta |  | 19d | 2024-11-08 | 2024-11-26 | A7340 SS | 19d | 0d | HH [152 h]; MADERA TORNILLO [7358 und] |  |
| A1780 |  | Acero de refuerzo f'y=4200kg/cm2 |  | 27d | 2024-11-08 | 2024-12-04 | A7340 SS | 17d | 1d | HH [208 h]; acero [137972] |  |
| A1740 |  | Concreto clase c (f'c=280 kg/cm2) premezclado - cimientos reforzados |  | 18d | 2024-11-11 | 2024-11-28 | A1780 SS+2d, A1730 SS+3d, A1760 SS | 16d | 0d | HH [144 h]; CONCRETO PREMEZCLADO F'C=280 kg/cm2 CON CEMENTO T-I [758]; PIEDRA CHANCADA [782.89]; ARENA GRUESA [757.44]; CEMENTO PORTLAND TIPO I (42.5 kg) [12701.6] |  |
| A1750 |  | Concreto clase c (f'c=280 kg/cm2) premezclado - muros de contencion |  | 13d | 2024-11-11 | 2024-11-23 | A1740 SS | 16d | 0d | HH [104 h]; CONCRETO PREMEZCLADO F'C=280 kg/cm2 CON CEMENTO T-I [553] |  |
| A1800 |  | Geocompuesto de drenaje |  | 13d | 2024-11-16 | 2024-11-28 | A1730 | 5d | 0d | HH [16 h] |  |
| A1810 |  | Tubo pvc - d=6'' d=4'' |  | 7d | 2024-11-16 | 2024-11-22 | A1730 | 39d | 34d | HH [48 h] |  |
| A1790 |  | Pintura bituminosa |  | 15d | 2024-11-24 | 2024-12-08 | A1750 | 23d | 18d | HH [120 h]; PINTURA ASFALTICA [1727] |  |
| A1830 |  | Tunta de dilatación |  | 10d | 2024-11-24 | 2024-12-03 | A1750 | 16d | 11d | HH [72 h] |  |
|  | 11 | **I-11-PT** |  |  | 2024-07-27 | 2024-12-24 |  |  |  |  |  |
| A7420 |  | Inicio I-11-PT-88+555.14 - Entrega de terreno liberado | milestone | 0d | 2024-07-27 | 2024-07-27 | A4740 SS | 8d | 0d |  |  |
| A7430 |  | Fin I-11-PT-88+555.14 - Entrega de terreno liberado | milestone | 0d | 2024-12-24 | 2024-12-24 | A2540 FF, A6160 FF, A6140 FF | 7d |  |  |  |

| ID | WBS | Activity | Type | Duration | Start | Finish | Predecessors | Total float | Free float | Resources | Cost |
| --- | --- | --- | --- | --- | --- | --- | --- | --- | --- | --- | --- |
|  | 1 | **DIQUE** |  |  | 2024-07-27 | 2024-12-24 |  |  |  |  |  |
|  | 1 | **Excavaciones** |  |  | 2024-07-27 | 2024-08-19 |  |  |  |  |  |
| A2430 |  | Desbroce |  | 4d | 2024-07-27 | 2024-07-30 | A7420 SS | 13d | 0d | Excavator [32 h]; HH [32 h] | 2,240 |
| A2440 |  | Excavacion de cimentación |  | 20d | 2024-07-27 | 2024-08-15 | A2430 SS | 13d | 0d | Excavator [160 h]; HH [160 h] | 11,200 |
| A2450 |  | Perfilado y conformación de plataforma de fundación |  | 15d | 2024-07-31 | 2024-08-14 | A2440 SS+4d | 13d | 0d | HH [120 h] |  |
| A2460 |  | Excavacion de uña |  | 20d | 2024-07-31 | 2024-08-19 | A2440 SS, A2450 SS | 13d | 6d | Excavator [160 h]; HH [160 h] | 11,200 |
|  | 2 | **Rellenos** |  |  | 2024-07-30 | 2024-08-23 |  |  |  |  |  |
| A2470 |  | Relleno con material granular (incluye extracción de material, zarandeo y / combinación de material) |  | 18d | 2024-07-30 | 2024-08-16 | A2440 SS+3d | 82d | 0d | HH [144 h]; MONEDA [8429.94] | 8,429.94 |
| A2490 |  | Relleno con material seleccionado (incluye extracción de material, / zarandeo y combinación de material) en sobreex |  | 19d | 2024-08-01 | 2024-08-19 | A2440 SS+5d | 77d | 0d | HH [152 h]; Cerco [3138.63] |  |
| A2480 |  | Perfilado de talud del dique |  | 15d | 2024-08-03 | 2024-08-17 | A2470 SS+4d | 82d | 5d | HH [120 h] |  |
| A2500 |  | Relleno mejorado con cemento |  | 15d | 2024-08-09 | 2024-08-23 | A2490 SS+8d | 77d | 0d | HH [120 h]; Relleno mejorado con Cemento [1256] |  |
|  | 3 | **Geotextil** |  |  | 2024-08-14 | 2024-09-16 |  |  |  |  |  |
| A2520 |  | Zanja de anclaje |  | 9d | 2024-08-14 | 2024-08-22 | A2500 SS+5d | 77d | 0d | HH [72 h] |  |
| A2510 |  | Instalación de geotextil 400 gr/m2 |  | 25d | 2024-08-23 | 2024-09-16 | A2520, A2480 | 77d | 70d | HH [200 h]; Geotextil [26283] |  |
|  | 4 | **Colocacion de Roca** |  |  | 2024-08-26 | 2024-12-24 |  |  |  |  |  |
| A2530 |  | Colocación de roca en uña |  | 67d | 2024-08-26 | 2024-10-31 | A7942 SS, A2460 | 7d | 0d | Excavator [176 h]; HH [176 h]; Roca [15569 m3] | 12,320 |
| A2540 |  | Colocación de roca en talud |  | 54d | 2024-11-01 | 2024-12-24 | A2530, A2510 SS, A2460 | 7d | 0d | Excavator [280 h]; HH [280 h]; Roca [17371.5 m3] | 19,600 |
|  | 5 | **Transporte** |  |  | 2024-07-30 | 2024-12-24 |  |  |  |  |  |
| A6130 |  | Transporte de material de prestamo (afirmado) |  | 18d | 2024-07-30 | 2024-08-16 | A2470 SS | 146d | 0d | HH [64 h] |  |
| A6150 |  | Transporte de material de préstamo cantera de rio (cuerpo de terraplén) |  | 18d | 2024-07-30 | 2024-08-16 | A2470 SS, A6130 SS | 146d | 15d | HH [64 h] |  |
| A6160 |  | Transporte de material seleccionado para zanja |  | 9d | 2024-08-14 | 2024-08-22 | A2520 SS, A6150 SS | 131d | 124d | HH [32 h] |  |
| A6140 |  | Transporte de roca |  | 121d | 2024-08-26 | 2024-12-24 | A2530 SS | 7d | 0d | HH [456 h] |  |
|  | 14 | **I-08-DI - Muro** |  |  | 2024-10-10 | 2024-12-23 |  |  |  |  |  |
| A7440 |  | Inicio I-08-DI-108+225.70 - Entrega de terreno liberado | milestone | 0d | 2024-10-10 | 2024-10-10 | A7420 SS+75d | 8d | 0d |  |  |
| A7450 |  | Fin I-08-DI-108+225.70 - Entrega de terreno liberado | milestone | 0d | 2024-12-23 | 2024-12-23 | A2930 FF, A2870 FF, A2880 FF, A4830 FF | 8d |  |  |  |

| ID | WBS | Activity | Duration | Start | Finish | Predecessors | Total float | Free float | Resources | Cost |
| --- | --- | --- | --- | --- | --- | --- | --- | --- | --- | --- |
|  | 1 | **DIQUE** |  | 2024-10-11 | 2024-12-23 |  |  |  |  |  |
|  | 1 | **Excavaciones** |  | 2024-10-11 | 2024-10-28 |  |  |  |  |  |
| A2810 |  | Desbroce | 1d | 2024-10-11 | 2024-10-11 | A7440 SS+1d | 8d | 0d | Excavator [8 h]; HH [8 h] | 560 |
| A2820 |  | Excavacion de cimentación | 7d | 2024-10-11 | 2024-10-17 | A2810 SS | 8d | 0d | Excavator [56 h]; HH [56 h] | 3,920 |
| A2830 |  | Perfilado y conformación de plataforma de fundación | 6d | 2024-10-12 | 2024-10-17 | A2820 SS+1d | 12d | 0d | HH [32 h] |  |
| A2840 |  | Excavacion de uña | 11d | 2024-10-18 | 2024-10-28 | A2820, A2830 | 12d | 4d | Excavator [128 h]; HH [128 h] | 8,960 |
|  | 2 | **Rellenos** |  | 2024-10-18 | 2024-11-16 |  |  |  |  |  |
| A2860 |  | Perfilado de talud del dique | 1d | 2024-10-18 | 2024-10-18 | A2820 | 73d | 2d | HH [8 h] |  |
| A2850 |  | Relleno con material granular (incluye extracción de material, zarandeo y / combinación de material) | 1d | 2024-10-20 | 2024-10-20 | A2820 FS+2d | 8d | 0d | HH [8 h]; MONEDA [208.14] | 208.14 |
| A2870 |  | Relleno mejorado con cemento | 1d | 2024-10-21 | 2024-10-21 | A2850, A2860 | 71d | 63d | HH [8 h]; Relleno mejorado con Cemento [131.72] |  |
| A2880 |  | Relleno estructural | 9d | 2024-11-08 | 2024-11-16 | A4890, A4850 | 45d | 37d | HH [64 h]; Relleno estructural [718] |  |
|  | 3 | **Geotextiles** |  | 2024-10-21 | 2024-11-01 |  |  |  |  |  |
| A2900 |  | Zanja de anclaje | 2d | 2024-10-21 | 2024-10-22 | A2850 | 8d | 0d | HH [16 h] |  |
| A2890 |  | Instalación de geotextil 400 gr/m2 | 10d | 2024-10-23 | 2024-11-01 | A2900 | 8d | 0d | HH [80 h]; Geotextil [7768] |  |
|  | 4 | **Colocacion de Roca** |  | 2024-11-02 | 2024-12-23 |  |  |  |  |  |
| A2910 |  | Colocación de roca en uña | 25d | 2024-11-02 | 2024-11-26 | A4850 SS+2d, A2890, A2840, A7942 SS | 8d | 0d | Excavator [80 h]; HH [80 h]; Roca [4350.81 m3] | 5,600 |
| A2920 |  | Colocación de roca en talud | 25d | 2024-11-27 | 2024-12-21 | A2910, A8140 | 8d | 0d | Excavator [152 h]; HH [144 h]; Roca [2986.31 m3] | 10,640 |
| A2930 |  | Colocación de roca en corona | 2d | 2024-12-22 | 2024-12-23 | A2920 | 8d | 0d | Excavator [8 h]; HH [8 h]; Roca [105.39 m3] | 560 |
|  | 5 | **Transporte** |  | 2024-10-11 | 2024-12-09 |  |  |  |  |  |
| A6170 |  | Transporte de material orgánico (a dmo) | 1d | 2024-10-11 | 2024-10-11 | A2810 SS | 43d | 21d | HH [16 h] |  |
| A6210 |  | Transporte de material de préstamo | 2d | 2024-10-21 | 2024-10-22 | A2850 SS, A6220 SS | 70d | 48d | HH [120 h] |  |
| A6220 |  | Transporte de material seleccionado para zanja | 2d | 2024-10-21 | 2024-10-22 | A2900 SS | 70d | 0d | HH [16 h] |  |
| A6200 |  | Transporte de roca | 38d | 2024-11-02 | 2024-12-09 | A2910 SS, A6170, A6210 FF | 22d |  | HH [232 h] |  |
|  | 5 | **MURO** |  | 2024-10-18 | 2024-11-07 |  |  |  |  |  |
| A4790 |  | Concreto de nivelacion (f'c=100 kg/cm2) | 2d | 2024-10-18 | 2024-10-19 | A2820 | 9d | 0d | HH [16 h]; CONCRETO PREMEZCLADO F'C=100 kg/cm2 CON CEMENTO T-I [36] |  |
| A4840 |  | Acero de refuerzo f'y=4200kg/cm2 | 11d | 2024-10-18 | 2024-10-28 | A2820 | 8d | 0d | HH [88 h]; acero [23586] |  |
| A4820 |  | Encofrado y desencofrado caravista | 8d | 2024-10-19 | 2024-10-26 | A4790 SS+1d | 59d | 0d | HH [64 h] |  |
| A4800 |  | Concreto clase c (f'c=280 kg/cm2) premezclado - cimientos reforzados | 9d | 2024-10-20 | 2024-10-28 | A4840 SS+2d | 8d | 0d | HH [72 h]; CONCRETO PREMEZCLADO F'C=280 kg/cm2 CON CEMENTO T-I [122.4]; PIEDRA CHANCADA [118.49]; ARENA GRUESA [114.64]; CEMENTO PORTLAND TIPO I (42.5 kg) [1922.44] |  |
| A4830 |  | Encofrado y desencofrado cara oculta | 11d | 2024-10-23 | 2024-11-02 | A4790 SS+4d, A4820 SS+4d | 59d | 51d | HH [88 h]; MADERA TORNILLO [1135 und] |  |
| A4810 |  | Concreto clase c (f'c=280 kg/cm2) premezclado - muros de contencion | 5d | 2024-10-26 | 2024-10-30 | A4790 FS+5d, A4800 SS+6d | 8d | 0d | HH [40 h]; CONCRETO PREMEZCLADO F'C=280 kg/cm2 CON CEMENTO T-I [88.13] |  |
| A4850 |  | Pintura bituminosa | 8d | 2024-10-31 | 2024-11-07 | A4810 | 8d | 0d | HH [280.83 h]; PINTURA ASFALTICA [434.6] |  |
| A4890 |  | Junta de dilatación | 2d | 2024-10-31 | 2024-11-01 | A4810 | 51d | 6d | HH [16 h] |  |

| ID | WBS | Activity | Duration | Start | Finish | Predecessors | Total float | Free float | Resources |
| --- | --- | --- | --- | --- | --- | --- | --- | --- | --- |
|  | PERIODO LLUVIAS | **PERIODO DE LLUVIAS** |  | 2025-01-01 | 2025-04-30 |  |  |  |  |
| A5370 |  | Periodo de Lluvias | 120d | 2025-01-01 | 2025-04-30 | A2930, A1670, A1530, A7390, A7330, A7430, A7450, A6200, A7951, A7949, A7350 | 0d |  | HH [960 h] |
|  | 2 | **CONSTRUCCION DIQUES 2025** |  | 2025-03-12 | 2025-09-21 |  |  |  |  |
| A8010 |  | Produccion de roca en cantera Cumbre | 165d | 2025-03-12 | 2025-08-23 | A5370 SS+70d | 43d | 34d |  |
| A8020 |  | Produccion de roca en cantera 121 | 180d | 2025-03-12 | 2025-09-07 | A5370 SS+70d | 16d | 0d |  |
| A7961 |  | Suministro de Roca cantera 121 | 142d | 2025-05-01 | 2025-09-19 | A5370 SS+120d, A8020 SS+50d | 16d | 2d |  |
| A7962 |  | Suministro de Roca cantera cumbre | 144d | 2025-05-01 | 2025-09-21 | A5370 SS+120d, A8010 SS+16d | 14d |  |  |
| A8270 |  | Suministro de roca en cantera Tres Montones para 2025 | 115d | 2025-05-01 | 2025-08-23 | A5370, A8260 | 10d |  |  |
|  | 1 | **SOLUCION DE INTERFERENCIAS** |  | 2025-05-01 | 2025-08-25 |  |  |  |  |
| A8070 |  | Solucion de interferencias Dique D-05-DI (CAN01 - Tipo canal) | 12d | 2025-05-01 | 2025-05-12 | A1280 SS | 146d |  |  |
| A8190 |  | Solucion de interferencias en Muro I-02-DI (INT 01 - Tipo tubo) | 28d | 2025-05-01 | 2025-05-28 | A4170 SS | 130d | 19d |  |
| A8240 |  | Solucion de interferencias Dique I-05-PT (INT 01 INT 02- Tipo tubo) | 28d | 2025-05-01 | 2025-05-28 | A3540 SS | 37d | 13d |  |
| A8060 |  | Solucion de interferencias Dique D-05-DI (INT 01 - Tipo tubo) | 12d | 2025-05-02 | 2025-05-13 | A1280 | 30d | 13d |  |
| A8100 |  | Solucion de interferencias Dique I-14-PT (INT 01 - Tipo tubo) | 18d | 2025-05-21 | 2025-06-07 | A1940 | 2d |  |  |
| A8110 |  | Solucion de interferencias Dique I-14-PT (CAN01 - Tip o canal) | 18d | 2025-05-21 | 2025-06-07 | A1940 | 2d |  |  |
| A8210 |  | Solucion de interferencias Dique I-01-PT (INT 01 INT 02- Tipo tubo) | 18d | 2025-06-02 | 2025-06-19 | A4620 | 48d | 3d |  |
| A8130 |  | Solucion de interferencias Dique I-09-PT (INT 01 - Tipo tubo) | 11d | 2025-06-17 | 2025-06-27 | A2670 FS+2d | 31d | 14d |  |
| A8170 |  | Solucion de interferencias Dique I-04-DI (CAN01 I-04-DI-CAN02- Tipo canal) | 15d | 2025-07-01 | 2025-07-15 | A3640 | 12d | 0d |  |
| A8180 |  | Solucion de interferencias Dique I-04-DI (TL01 - Tipo tubo) | 15d | 2025-07-01 | 2025-07-15 | A3640 | 12d | 0d |  |
| A8250 |  | Solucion de interferencias Dique D-03-DI | 12d | 2025-07-05 | 2025-07-16 | A3020 | 49d | 4d |  |
| A8230 |  | Solucion de interferencias Dique I-04-2-DI | 8d | 2025-07-10 | 2025-07-17 | A3790 | 27d | 3d |  |
| A8200 |  | Solucion de interferencias Dique -13A-PT (INT 01 - Tipo tubo) | 13d | 2025-07-23 | 2025-08-04 | A2190 | 4d |  |  |
| A8160 |  | Solucion de interferencias I-07-DI (INT 01 - Tipo tubo) | 23d | 2025-07-27 | 2025-08-18 | A3150 FS+1d | 14d | 2d |  |
| A8120 |  | Solucion de interferencias Dique I-10-PT (INT 01 - Tipo tubo) | 21d | 2025-08-02 | 2025-08-22 | A2550 FS+1d | 28d | 11d |  |
| A8220 |  | Solucion de interferencias Dique D-01-DI (INT 01 INT 02 - Tipo tubo) | 9d | 2025-08-17 | 2025-08-25 | A4040 | 30d | 6d |  |

| ID | WBS | Activity | Type | Duration | Start | Finish | Predecessors | Total float | Free float | Resources | Cost |
| --- | --- | --- | --- | --- | --- | --- | --- | --- | --- | --- | --- |
|  | 6 | **I-15-3-DI** |  |  | 2025-05-01 | 2025-05-19 |  |  |  |  |  |
| A7460 |  | Inicio I-15-3-DI-67+883.31 - Entrega de terreno liberado | milestone | 0d | 2025-05-01 | 2025-05-01 | A5370 | 0d |  |  |  |
| A7470 |  | Fin I-15-3-DI-67+883.31 - Entrega de terreno liberado | milestone | 0d | 2025-05-19 | 2025-05-19 | A1930 FF | 139d | 125d |  |  |
|  | 1 | **DIQUE** |  |  | 2025-05-01 | 2025-05-19 |  |  |  |  |  |
|  | 1 | **Excavaciones** |  |  | 2025-05-01 | 2025-05-10 |  |  |  |  |  |
| A1840 |  | Desbroce |  | 1d | 2025-05-01 | 2025-05-01 | A7460 SS | 0d |  | Excavator [8 h]; HH [8 h] | 560 |
| A1850 |  | Excavacion de cimentación |  | 7d | 2025-05-02 | 2025-05-08 | A1840 | 0d |  | Excavator [56 h]; HH [56 h] | 3,920 |
| A1860 |  | Perfilado y conformación de plataforma de fundación |  | 2d | 2025-05-06 | 2025-05-07 | A1850 SS+4d | 1d | 0d | HH [16 h] |  |
| A1870 |  | Excavacion de uña |  | 2d | 2025-05-09 | 2025-05-10 | A1850, A1860 | 0d |  | Excavator [16 h]; HH [16 h] | 1,120 |
|  | 2 | **Rellenos** |  |  | 2025-05-08 | 2025-05-09 |  |  |  |  |  |
| A1880 |  | Relleno con material granular (incluye extracción de material, zarandeo y / combinación de material) |  | 1d | 2025-05-08 | 2025-05-08 | A1860 | 1d | 0d | HH [8 h]; MONEDA [15] | 15 |
| A1890 |  | Relleno mejorado con cemento |  | 1d | 2025-05-09 | 2025-05-09 | A1880 | 1d | 0d | HH [8 h]; Relleno mejorado con Cemento [109.02] |  |
|  | 3 | **Geotextil** |  |  | 2025-05-09 | 2025-05-12 |  |  |  |  |  |
| A1910 |  | Zanja de anclaje |  | 1d | 2025-05-09 | 2025-05-09 | A1880 | 1d | 0d | HH [8 h] |  |
| A1900 |  | Instalación de geotextil 400 gr/m2 |  | 3d | 2025-05-10 | 2025-05-12 | A1910, A1890 | 1d |  | HH [16 h]; Geotextil [3750] |  |
|  | 4 | **Colocacion de Roca** |  |  | 2025-05-11 | 2025-05-19 |  |  |  |  |  |
| A1920 |  | Colocación de roca en uña |  | 5d | 2025-05-11 | 2025-05-15 | A1870, A1900 SS, A8270 SS | 0d |  | Excavator [40 h]; HH [40 h]; Roca [1182.98 m3] | 2,800 |
| A1930 |  | Colocación de roca en talud |  | 4d | 2025-05-16 | 2025-05-19 | A1920 | 0d |  | Excavator [32 h]; HH [32 h]; Roca [649.34 m3] | 2,240 |
|  | 5 | **Transporte** |  |  | 2025-05-01 | 2025-05-19 |  |  |  |  |  |
| A6230 |  | Transporte de material orgánico (a dmo) |  | 1d | 2025-05-01 | 2025-05-01 | A1840 SS | 27d | 0d | HH [8 h] |  |
| A6240 |  | Transporte de material excedente |  | 9d | 2025-05-02 | 2025-05-10 | A1850 SS, A6230 | 27d | 9d | HH [72 h] |  |
| A6280 |  | Transporte de material seleccionado para zanja |  | 1d | 2025-05-09 | 2025-05-09 | A1910 SS | 19d | 0d | HH [8 h] |  |
| A6270 |  | Transporte de material de préstamo cantera de rio (cuerpo de terraplén) |  | 2d | 2025-05-10 | 2025-05-11 | A1890 SS, A6280 | 19d | 1d | HH [16 h] |  |
| A6260 |  | Transporte de roca |  | 9d | 2025-05-11 | 2025-05-19 | A1920 SS, A6240 SS, A6270 SS | 18d | 0d | HH [56 h] |  |

| ID | WBS | Activity | Type | Duration | Start | Finish | Predecessors | Total float | Free float | Resources | Cost |
| --- | --- | --- | --- | --- | --- | --- | --- | --- | --- | --- | --- |
|  | 7 | **I-14-1-PT** |  |  | 2025-05-20 | 2025-06-24 |  |  |  |  |  |
| A7480 |  | Inicio I-14-1-PT-68+715.78 - Entrega de terreno liberado | milestone | 0d | 2025-05-20 | 2025-05-20 | A1930 | 0d |  |  |  |
| A7490 |  | Fin I-14-1-PT-68+715.78 - Entrega de terreno liberado | milestone | 0d | 2025-06-24 | 2025-06-24 | A2060 FF, A6330 FF | 103d | 89d |  |  |
|  | 1 | **DIQUE** |  |  | 2025-05-20 | 2025-06-24 |  |  |  |  |  |
|  | 1 | **Excavaciones** |  |  | 2025-05-20 | 2025-06-19 |  |  |  |  |  |
| A1940 |  | Desbroce |  | 1d | 2025-05-20 | 2025-05-20 | A7480 SS | 0d |  | Excavator [8 h]; HH [8 h] | 560 |
| A1950 |  | Excavacion de cimentación |  | 20d | 2025-05-21 | 2025-06-09 | A1940 | 0d |  | Excavator [160 h]; HH [160 h] | 11,200 |
| A1960 |  | Perfilado y conformación de plataforma de fundación |  | 8d | 2025-05-25 | 2025-06-01 | A1950 SS+4d | 1d | 0d | HH [64 h] |  |
| A1970 |  | Excavacion de uña |  | 10d | 2025-06-10 | 2025-06-19 | A1950, A1960 | 0d |  | Excavator [72 h]; HH [72 h] | 5,040 |
|  | 2 | **Rellenos** |  |  | 2025-05-26 | 2025-06-08 |  |  |  |  |  |
| A1980 |  | Relleno con material granular (incluye extracción de material, zarandeo y / combinación de material) |  | 5d | 2025-05-26 | 2025-05-30 | A1950 SS+5d | 1d | 0d | HH [40 h]; MONEDA [2487.99] | 2,487.99 |
| A1990 |  | Perfilado de talud del dique |  | 5d | 2025-05-26 | 2025-05-30 | A1980 SS | 122d | 0d | HH [40 h] |  |
| A2000 |  | Relleno con material seleccionado (incluye extracción de material, / zarandeo y combinación de material) en sobreex |  | 6d | 2025-05-31 | 2025-06-05 | A1980, A1990 | 122d | 4d | HH [40 h]; Cerco [943.7] |  |
| A2010 |  | Grava para drenaje |  | 4d | 2025-06-02 | 2025-06-05 | A1960 | 1d | 0d | HH [32 h]; Grava para drenaje [262.5] |  |
| A2020 |  | Relleno mejorado con cemento |  | 3d | 2025-06-06 | 2025-06-08 | A2010 | 1d |  | HH [16 h]; Relleno mejorado con Cemento [241] |  |
|  | 3 | **Geotextil** |  |  | 2025-05-27 | 2025-06-08 |  |  |  |  |  |
| A2040 |  | Zanja de anclaje |  | 3d | 2025-05-27 | 2025-05-29 | A1980 SS+1d | 1d | 0d | HH [16 h] |  |
| A2030 |  | Instalación de geotextil 400 gr/m2 |  | 10d | 2025-05-30 | 2025-06-08 | A2040 | 1d |  | HH [80 h]; Geotextil [7212] |  |
|  | 4 | **Colocacion de Roca** |  |  | 2025-05-24 | 2025-06-24 |  |  |  |  |  |
| A2050 |  | Colocación de roca en uña |  | 17d | 2025-05-24 | 2025-06-09 | A1950 SS+3d, A8270 SS | 0d |  | Excavator [136 h]; HH [136 h]; Roca [3977.89 m3] | 9,520 |
| A2060 |  | Colocación de roca en talud |  | 15d | 2025-06-10 | 2025-06-24 | A2050, A2020, A2030, A1970 SS, A1950, A8110, A8100 | 0d |  | Excavator [176 h]; HH [176 h]; Roca [3532.44 m3] | 12,320 |
|  | 5 | **Transporte** |  |  | 2025-05-20 | 2025-06-24 |  |  |  |  |  |
| A6290 |  | Transporte de material orgánico (a dmo) |  | 1d | 2025-05-20 | 2025-05-20 | A1940 SS, A6260 | 18d | 0d | HH [8 h] |  |
| A6300 |  | Transporte de material excedente |  | 30d | 2025-05-21 | 2025-06-19 | A1950 SS, A6290 | 18d | 3d | HH [232 h] |  |
| A6320 |  | Transporte de roca |  | 32d | 2025-05-24 | 2025-06-24 | A2050 SS, A6300 SS | 15d | 0d | HH [312 h] |  |
| A6340 |  | Transporte de material seleccionado para zanja |  | 3d | 2025-05-27 | 2025-05-29 | A2040 SS | 119d | 0d | HH [16 h] |  |
| A6310 |  | Transporte de material de prestamo (afirmado) |  | 5d | 2025-05-30 | 2025-06-03 | A1980 SS, A6340 | 119d | 0d | HH [40 h] |  |
| A6330 |  | Transporte de material de préstamo cantera de rio (cuerpo de terraplén) |  | 5d | 2025-06-04 | 2025-06-08 | A2000 SS, A6310 | 119d | 16d | HH [40 h] |  |

| ID | WBS | Activity | Type | Duration | Start | Finish | Predecessors | Total float | Free float | Resources | Cost |
| --- | --- | --- | --- | --- | --- | --- | --- | --- | --- | --- | --- |
|  | 8 | **I-14-2-PT** |  |  | 2025-06-25 | 2025-07-21 |  |  |  |  |  |
| A7500 |  | Inicio I-14-2-PT-68+432.64 - Entrega de terreno liberado | milestone | 0d | 2025-06-25 | 2025-06-25 | A2060 | 0d |  |  |  |
| A7510 |  | Fin I-14-2-PT-68+432.64 - Entrega de terreno liberado | milestone | 0d | 2025-07-21 | 2025-07-21 | A2180 FF, A6390 FF | 76d | 62d |  |  |
|  | 1 | **DIQUE** |  |  | 2025-06-25 | 2025-07-21 |  |  |  |  |  |
|  | 1 | **Excavaciones** |  |  | 2025-06-25 | 2025-07-09 |  |  |  |  |  |
| A2070 |  | Desbroce |  | 1d | 2025-06-25 | 2025-06-25 | A2060, A7500 SS | 0d |  | Excavator [8 h]; HH [8 h] | 560 |
| A2080 |  | Excavacion de cimentación |  | 6d | 2025-06-26 | 2025-07-01 | A2070 | 0d |  | Excavator [48 h]; HH [48 h] | 3,360 |
| A2090 |  | Perfilado y conformación de plataforma de fundación |  | 3d | 2025-06-28 | 2025-06-30 | A2080 SS+2d | 1d |  | HH [24 h] |  |
| A2100 |  | Excavacion de uña |  | 8d | 2025-07-02 | 2025-07-09 | A2080, A2090 | 0d |  | Excavator [64 h]; HH [64 h] | 4,480 |
|  | 2 | **Rellenos** |  |  | 2025-06-27 | 2025-07-03 |  |  |  |  |  |
| A2110 |  | Relleno con material granular (incluye extracción de material, zarandeo y / combinación de material) |  | 2d | 2025-06-27 | 2025-06-28 | A2080 SS+1d | 5d | 0d | HH [16 h]; MONEDA [969] | 969 |
| A2120 |  | Perfilado de talud del dique |  | 1d | 2025-06-28 | 2025-06-28 | A2110 SS+1d | 6d | 0d | HH [8 h] |  |
| A2130 |  | Relleno con material seleccionado (incluye extracción de material, / zarandeo y combinación de material) en sobreex |  | 3d | 2025-06-29 | 2025-07-01 | A2110, A2120 | 6d | 0d | HH [16 h]; Cerco [421.44] |  |
| A2140 |  | Relleno mejorado con cemento |  | 2d | 2025-07-02 | 2025-07-03 | A2130 | 6d |  | HH [16 h]; Relleno mejorado con Cemento [178] |  |
|  | 3 | **Geotextil** |  |  | 2025-06-29 | 2025-07-04 |  |  |  |  |  |
| A2160 |  | Zanja de anclaje |  | 2d | 2025-06-29 | 2025-06-30 | A2110 | 5d | 0d | HH [8 h] |  |
| A2150 |  | Instalación de geotextil 400 gr/m2 |  | 4d | 2025-07-01 | 2025-07-04 | A2160 | 5d |  | HH [32 h]; Geotextil [5866] |  |
|  | 4 | **Colocacion de Roca** |  |  | 2025-06-29 | 2025-07-21 |  |  |  |  |  |
| A2170 |  | Colocación de roca en uña |  | 11d | 2025-06-29 | 2025-07-09 | A2080 SS+3d, A8270 SS | 0d |  | Excavator [88 h]; HH [88 h]; Roca [3150.28 m3] | 6,160 |
| A2180 |  | Colocación de roca en talud |  | 12d | 2025-07-10 | 2025-07-21 | A2170, A2100, A2140, A2150 | 0d |  | Excavator [96 h]; HH [96 h]; Roca [2382.6 m3] | 6,720 |
|  | 5 | **Transporte** |  |  | 2025-06-25 | 2025-07-21 |  |  |  |  |  |
| A6350 |  | Transporte de material orgánico (a dmo) |  | 1d | 2025-06-25 | 2025-06-25 | A2070 SS, A6320 | 15d | 0d | HH [8 h] |  |
| A6360 |  | Transporte de material excedente |  | 14d | 2025-06-26 | 2025-07-09 | A2080 SS, A6350 | 15d | 3d | HH [104 h] |  |
| A6370 |  | Transporte de material de prestamo (afirmado) |  | 2d | 2025-06-27 | 2025-06-28 | A2110 SS | 97d | 1d | HH [16 h] |  |
| A6380 |  | Transporte de roca |  | 23d | 2025-06-29 | 2025-07-21 | A2170 SS, A6360 SS | 12d | 0d | HH [224 h] |  |
| A6400 |  | Transporte de material seleccionado para zanja |  | 1d | 2025-06-29 | 2025-06-29 | A2160 SS | 96d | 0d | HH [8 h] |  |
| A6390 |  | Transporte de material de préstamo cantera de rio (cuerpo de terraplén) |  | 2d | 2025-06-30 | 2025-07-01 | A2130 SS, A6370, A6400 | 96d | 20d | HH [16 h] |  |

| ID | WBS | Activity | Type | Duration | Start | Finish | Predecessors | Total float | Free float | Resources | Cost |
| --- | --- | --- | --- | --- | --- | --- | --- | --- | --- | --- | --- |
|  | 9 | **I-13A-PT** |  |  | 2025-07-22 | 2025-08-23 |  |  |  |  |  |
| A7520 |  | Inicio I-13A-PT-71+388.29 - Entrega de terreno liberado | milestone | 0d | 2025-07-22 | 2025-07-22 | A2180 | 0d |  |  |  |
| A7530 |  | Fin I-13A-PT-71+388.29 - Entrega de terreno liberado | milestone | 0d | 2025-08-23 | 2025-08-23 | A2310 FF+1d | 43d | 29d |  |  |
|  | 1 | **DIQUE** |  |  | 2025-07-22 | 2025-08-22 |  |  |  |  |  |
|  | 1 | **Excavaciones** |  |  | 2025-07-22 | 2025-08-08 |  |  |  |  |  |
| A2190 |  | Desbroce |  | 1d | 2025-07-22 | 2025-07-22 | A7520 SS | 0d |  | Excavator [8 h]; HH [8 h] | 560 |
| A2200 |  | Excavacion de cimentación |  | 11d | 2025-07-23 | 2025-08-02 | A2190 | 0d |  | Excavator [88 h]; HH [88 h] | 6,160 |
| A2210 |  | Perfilado y conformación de plataforma de fundación |  | 7d | 2025-07-26 | 2025-08-01 | A2200 SS+3d | 1d |  | HH [56 h] |  |
| A2220 |  | Excavacion de uña |  | 6d | 2025-08-03 | 2025-08-08 | A2200, A2210 | 0d |  | Excavator [48 h]; HH [48 h] | 3,360 |
|  | 2 | **Rellenos** |  |  | 2025-07-26 | 2025-08-03 |  |  |  |  |  |
| A2230 |  | Relleno con material granular (incluye extracción de material, zarandeo y / combinación de material) |  | 1d | 2025-07-26 | 2025-07-26 | A2200 SS+3d | 5d | 0d | HH [8 h]; MONEDA [369.21] | 369.21 |
| A2240 |  | Relleno sin compactar |  | 3d | 2025-07-26 | 2025-07-28 | A2230 SS | 5d | 0d | HH [24 h] |  |
| A2250 |  | Perfilado de talud del dique |  | 1d | 2025-07-26 | 2025-07-26 | A2230 SS | 7d | 2d | HH [8 h] |  |
| A2260 |  | Relleno con material seleccionado (incluye extracción de material, / zarandeo y combinación de material) en sobreex |  | 4d | 2025-07-29 | 2025-08-01 | A2240, A2250 | 5d | 0d | HH [32 h]; Cerco [1591.98] |  |
| A2270 |  | Relleno mejorado con cemento |  | 2d | 2025-08-02 | 2025-08-03 | A2260 | 5d |  | HH [16 h]; Relleno mejorado con Cemento [222] |  |
|  | 3 | **Geotextil** |  |  | 2025-07-26 | 2025-08-03 |  |  |  |  |  |
| A2290 |  | Zanja de anclaje |  | 1d | 2025-07-26 | 2025-07-26 | A2240 SS | 5d | 0d | HH [8 h] |  |
| A2280 |  | Instalación de geotextil 400 gr/m2 |  | 8d | 2025-07-27 | 2025-08-03 | A2290 | 5d |  | HH [64 h]; Geotextil [3946] |  |
|  | 4 | **Colocacion de Roca** |  |  | 2025-07-29 | 2025-08-22 |  |  |  |  |  |
| A2300 |  | Colocación de roca en uña |  | 11d | 2025-07-29 | 2025-08-08 | A2200 SS+6d, A8270 SS | 0d |  | Excavator [88 h]; HH [88 h]; Roca [2693.74 m3] | 6,160 |
| A2310 |  | Colocación de roca en talud |  | 14d | 2025-08-09 | 2025-08-22 | A2300, A2220, A2270, A2280, A8200 | 0d |  | Excavator [96 h]; HH [96 h]; Roca [2283.16 m3] | 6,720 |
|  | 5 | **Transporte** |  |  | 2025-07-22 | 2025-08-22 |  |  |  |  |  |
| A6410 |  | Transporte de material orgánico (a dmo) |  | 1d | 2025-07-22 | 2025-07-22 | A2190 SS, A6380 | 12d | 0d | HH [8 h] |  |
| A6420 |  | Transporte de material excedente |  | 17d | 2025-07-23 | 2025-08-08 | A2200 SS, A6410 | 12d | 6d | HH [136 h] |  |
| A6460 |  | Transporte de material seleccionado para zanja |  | 1d | 2025-07-26 | 2025-07-26 | A2290 SS | 7d | 0d | HH [8 h] |  |
| A6430 |  | Transporte de material de prestamo (afirmado) |  | 1d | 2025-07-27 | 2025-07-27 | A2230 SS, A6460 | 7d | 1d | HH [8 h] |  |
| A6440 |  | Transporte de roca |  | 25d | 2025-07-29 | 2025-08-22 | A2300 SS, A6420 SS, A6450 SS | 6d | 0d | HH [184 h] |  |
| A6450 |  | Transporte de material de préstamo cantera de rio (cuerpo de terraplén) |  | 4d | 2025-07-29 | 2025-08-01 | A2260 SS, A6430 | 6d | 0d | HH [32 h] |  |

| ID | WBS | Activity | Type | Duration | Start | Finish | Predecessors | Total float | Free float | Resources | Cost |
| --- | --- | --- | --- | --- | --- | --- | --- | --- | --- | --- | --- |
|  | 10 | **I-12-PT** |  |  | 2025-08-23 | 2025-09-21 |  |  |  |  |  |
| A7540 |  | Inicio I-12-PT-83+262.94 - Entrega de terreno liberado | milestone | 0d | 2025-08-23 | 2025-08-23 | A2310 | 0d |  |  |  |
| A7550 |  | Fin I-12-PT-83+262.94 - Entrega de terreno liberado | milestone | 0d | 2025-09-21 | 2025-09-21 | A2420 FF, A6500 FF | 0d |  |  |  |
|  | 1 | **DIQUE** |  |  | 2025-08-23 | 2025-09-21 |  |  |  |  |  |
|  | 1 | **Excavaciones** |  |  | 2025-08-23 | 2025-09-15 |  |  |  |  |  |
| A2320 |  | Desbroce |  | 2d | 2025-08-23 | 2025-08-24 | A7540 SS | 0d |  | Excavator [16 h]; HH [16 h] | 1,120 |
| A2330 |  | Excavacion de cimentación |  | 12d | 2025-08-23 | 2025-09-03 | A2320 SS | 0d |  | Excavator [96 h]; HH [96 h] | 6,720 |
| A2340 |  | Perfilado y conformación de plataforma de fundación |  | 10d | 2025-08-24 | 2025-09-02 | A2330 SS+1d | 1d |  | HH [88 h] |  |
| A2350 |  | Excavacion de uña |  | 12d | 2025-09-04 | 2025-09-15 | A2330, A2340 | 0d |  | Excavator [88 h]; HH [88 h] | 6,160 |
|  | 2 | **Rellenos** |  |  | 2025-08-25 | 2025-09-07 |  |  |  |  |  |
| A2360 |  | Relleno con material granular (incluye extracción de material, zarandeo y / combinación de material) |  | 12d | 2025-08-25 | 2025-09-05 | A2330 SS+2d | 2d | 0d | HH [96 h]; MONEDA [5654.25] | 5,654.25 |
| A2370 |  | Perfilado de talud del dique |  | 8d | 2025-08-29 | 2025-09-05 | A2360 SS+4d | 28d | 0d | HH [64 h] |  |
| A2380 |  | Relleno mejorado con cemento |  | 2d | 2025-09-06 | 2025-09-07 | A2360, A2370 | 28d |  | HH [16 h]; Relleno mejorado con Cemento [164] |  |
|  | 3 | **Geotextil** |  |  | 2025-08-29 | 2025-09-13 |  |  |  |  |  |
| A2400 |  | Zanja de anclaje |  | 3d | 2025-08-29 | 2025-08-31 | A2360 SS+4d | 2d | 0d | HH [24 h] |  |
| A2390 |  | Instalación de geotextil 400 gr/m2 |  | 13d | 2025-09-01 | 2025-09-13 | A2400 | 9d |  | HH [104 h]; Geotextil [6362.83] |  |
|  | 4 | **Colocacion de Roca** |  |  | 2025-08-30 | 2025-09-21 |  |  |  |  |  |
| A2410 |  | Colocación de roca en uña |  | 11d | 2025-08-30 | 2025-09-09 | A2330 SS+7d, A7961 SS, A7962 SS | 0d |  | Excavator [80 h]; HH [80 h]; Roca [4933.41 m3] | 5,600 |
| A2420 |  | Colocación de roca en talud |  | 12d | 2025-09-10 | 2025-09-21 | A2410, A2390 SS, A2330, A2350 SS+6d | 0d |  | Excavator [104 h]; HH [104 h]; Roca [5504.74 m3] | 7,280 |
|  | 5 | **Transporte** |  |  | 2025-08-23 | 2025-09-20 |  |  |  |  |  |
| A6470 |  | Transporte de material orgánico (a dmo) |  | 2d | 2025-08-23 | 2025-08-24 | A2320 SS, A6440 | 6d | 0d | HH [16 h] |  |
| A6480 |  | Transporte de material excedente |  | 22d | 2025-08-25 | 2025-09-15 | A2330 SS, A6470 | 6d | 5d | HH [200 h] |  |
| A6490 |  | Transporte de material de prestamo (afirmado) |  | 12d | 2025-08-25 | 2025-09-05 | A2360 SS | 6d | 4d | HH [96 h] |  |
| A6520 |  | Transporte de material seleccionado para zanja |  | 2d | 2025-08-29 | 2025-08-30 | A2400 SS, A6490 SS | 2d | 1d | HH [24 h] |  |
| A6500 |  | Transporte de roca |  | 22d | 2025-08-30 | 2025-09-20 | A2410 SS, A6480 SS, A6520 SS | 1d |  | HH [184 h] |  |

| ID | WBS | Activity | Type | Duration | Start | Finish | Predecessors | Total float | Free float | Resources | Cost |
| --- | --- | --- | --- | --- | --- | --- | --- | --- | --- | --- | --- |
|  | 2 | **D-05-DI** |  |  | 2025-05-01 | 2025-06-13 |  |  |  |  |  |
| A7360 |  | Inicio D-05-DI-59+855.20 - Entrega de terreno liberado | milestone | 0d | 2025-05-01 | 2025-05-01 | A5370 | 17d | 0d |  |  |
| A7370 |  | Fin D-05-DI-59+855.20 - Entrega de terreno liberado | milestone | 0d | 2025-06-13 | 2025-06-13 | A1370 FF, A5960 FF | 114d |  |  |  |
|  | 1 | **DIQUE** |  |  | 2025-05-01 | 2025-06-13 |  |  |  |  |  |
|  | 1 | **Excavaciones** |  |  | 2025-05-01 | 2025-05-18 |  |  |  |  |  |
| A1280 |  | Desbroce |  | 1d | 2025-05-01 | 2025-05-01 | A7360 SS | 17d | 0d | Excavator [8 h]; HH [8 h] | 560 |
| A1290 |  | Excavacion de cimentación |  | 9d | 2025-05-01 | 2025-05-09 | A1280 SS | 17d | 0d | Excavator [64 h]; HH [64 h] | 4,480 |
| A1300 |  | Perfilado y conformación de plataforma de fundación |  | 4d | 2025-05-06 | 2025-05-09 | A1290 SS+5d | 29d | 4d | HH [24 h] |  |
| A1310 |  | Excavacion de uña |  | 9d | 2025-05-10 | 2025-05-18 | A1290, A1300 SS | 25d | 8d | Excavator [72 h]; HH [72 h] | 5,040 |
|  | 2 | **Rellenos** |  |  | 2025-05-01 | 2025-05-19 |  |  |  |  |  |
| A1320 |  | Relleno con material granular (incluye extracción de material, zarandeo y / combinación de material) |  | 13d | 2025-05-01 | 2025-05-13 | A1290 SS | 34d | 0d | HH [104 h]; MONEDA [6152.9] | 6,152.9 |
| A1330 |  | Perfilado de talud del dique |  | 6d | 2025-05-08 | 2025-05-13 | A1320 SS+7d | 139d | 0d | HH [48 h] |  |
| A1340 |  | Relleno con material seleccionado (incluye extracción de material, / zarandeo y combinación de material) en sobreex |  | 3d | 2025-05-08 | 2025-05-10 | A1330 SS | 139d | 0d | HH [16 h]; Cerco [419.29] |  |
| A1350 |  | Grava para drenaje |  | 6d | 2025-05-11 | 2025-05-16 | A1320 SS, A1360 SS | 142d | 0d | HH [40 h]; Grava para drenaje [366.22] |  |
| A1360 |  | Relleno material propio compactado |  | 9d | 2025-05-11 | 2025-05-19 | A1340 | 139d | 0d | HH [64 h] |  |
| A1370 |  | Relleno mejorado con cemento |  | 3d | 2025-05-11 | 2025-05-13 | A1350 SS | 145d | 31d | HH [16 h]; Relleno mejorado con Cemento [227] |  |
|  | 3 | **Geotextil** |  |  | 2025-05-04 | 2025-05-15 |  |  |  |  |  |
| A1390 |  | Zanja de anclaje |  | 3d | 2025-05-04 | 2025-05-06 | A1320 SS+3d | 34d | 0d | HH [16 h] |  |
| A1380 |  | Instalación de geotextil 400 gr/m2 |  | 9d | 2025-05-07 | 2025-05-15 | A1390 | 34d | 17d | HH [64 h]; Geotextil [6481] |  |
|  | 4 | **Colocacion de Roca** |  |  | 2025-05-11 | 2025-06-13 |  |  |  |  |  |
| A1400 |  | Colocación de roca en uña |  | 16d | 2025-05-11 | 2025-05-26 | A1290 SS+10d, A8270 SS | 17d | 0d | Excavator [120 h]; HH [120 h]; Roca [3585.86 m3] | 8,400 |
| A1410 |  | Colocación de roca en talud |  | 18d | 2025-05-27 | 2025-06-13 | A1400, A1380 SS+3d, A1310, A8060 | 17d | 0d | Excavator [136 h]; HH [136 h]; Roca [2819.15 m3] | 9,520 |
|  | 5 | **Transporte** |  |  | 2025-05-01 | 2025-06-13 |  |  |  |  |  |
| A5930 |  | Transporte de material orgánico (a dmo) |  | 1d | 2025-05-01 | 2025-05-01 | A1280 SS | 123d | 2d | HH [8 h] |  |
| A5940 |  | Transporte de material excedente |  | 18d | 2025-05-01 | 2025-05-18 | A1290 SS | 124d | 10d | HH [56 h] |  |
| A5970 |  | Transporte de material de préstamo cantera de rio (cuerpo de terraplén) |  | 13d | 2025-05-01 | 2025-05-13 | A1320 SS | 124d | 10d | HH [56 h] |  |
| A5980 |  | Transporte de material seleccionado para zanja |  | 3d | 2025-05-04 | 2025-05-06 | A1390 SS, A5930 | 121d | 7d | HH [16 h] |  |
| A5960 |  | Transporte de roca |  | 34d | 2025-05-11 | 2025-06-13 | A1400 SS, A5940 SS, A5970 SS, A5980 SS | 114d | 0d | HH [272 h]; Roca [272 m3] |  |

| ID | WBS | Activity | Type | Duration | Start | Finish | Predecessors | Total float | Free float | Resources | Cost |
| --- | --- | --- | --- | --- | --- | --- | --- | --- | --- | --- | --- |
|  | 13 | **I-09-PT** |  |  | 2025-06-14 | 2025-07-31 |  |  |  |  |  |
| A7400 |  | Inicio I-09-PT-93+520.79 - Entrega de terreno liberado | milestone | 0d | 2025-06-14 | 2025-06-14 | A1410 | 17d | 0d |  |  |
| A7410 |  | Fin I-09-PT-93+520.79 - Entrega de terreno liberado | milestone | 0d | 2025-07-31 | 2025-07-31 | A2760 FF, A2800 FF, A6060 FF, A6080 FF | 66d | 52d |  |  |
|  | 1 | **DIQUE** |  |  | 2025-06-14 | 2025-07-31 |  |  |  |  |  |
|  | 1 | **Excavaciones** |  |  | 2025-06-14 | 2025-07-03 |  |  |  |  |  |
| A2670 |  | Desbroce |  | 1d | 2025-06-14 | 2025-06-14 | A7400 SS | 17d | 0d | Excavator [8 h]; HH [8 h] | 560 |
| A2680 |  | Excavación de cimentación |  | 11d | 2025-06-15 | 2025-06-25 | A2670 | 17d | 0d | Excavator [88 h]; HH [88 h] | 6,160 |
| A2690 |  | Perfilado y conformación de plataforma de fundación |  | 9d | 2025-06-17 | 2025-06-25 | A2680 SS+2d | 26d | 9d | HH [72 h] |  |
| A2700 |  | Excavacion de uña |  | 8d | 2025-06-26 | 2025-07-03 | A2680, A2690 SS | 17d | 0d | Excavator [64 h]; HH [64 h] | 4,480 |
|  | 2 | **Rellenos** |  |  | 2025-06-16 | 2025-07-03 |  |  |  |  |  |
| A2710 |  | Relleno con material granular (incluye extracción de material, zarandeo y / combinación de material) |  | 2d | 2025-06-16 | 2025-06-17 | A2680 SS+1d | 35d | 0d | HH [16 h]; MONEDA [1013.28] | 1,013.28 |
| A2720 |  | Relleno sin compactar |  | 5d | 2025-06-18 | 2025-06-22 | A2710 | 35d | 0d | HH [40 h] |  |
| A2730 |  | Perfilado de talud del dique |  | 1d | 2025-06-18 | 2025-06-18 | A2720 SS | 35d | 0d | HH [8 h] |  |
| A2740 |  | Relleno con material seleccionado (incluye extracción de material, / zarandeo y combinación de material) en sobreex |  | 1d | 2025-06-19 | 2025-06-19 | A2710 SS, A2730 | 35d | 0d | HH [8 h]; Cerco [30.85] |  |
| A2750 |  | Grava para drenaje |  | 11d | 2025-06-20 | 2025-06-30 | A2720 SS, A2740 | 35d | 0d | HH [88 h]; Grava para drenaje [5619.43] |  |
| A2760 |  | Relleno mejorado con cemento |  | 3d | 2025-07-01 | 2025-07-03 | A2750 | 94d | 28d | HH [24 h]; Relleno mejorado con Cemento [284] |  |
|  | 3 | **Geotextil** |  |  | 2025-06-20 | 2025-06-30 |  |  |  |  |  |
| A2780 |  | Zanja de anclaje |  | 2d | 2025-06-20 | 2025-06-21 | A2750 SS | 35d | 0d | HH [16 h] |  |
| A2770 |  | Instalación de geotextil 400 gr/m2 |  | 9d | 2025-06-22 | 2025-06-30 | A2780 | 35d | 18d | HH [72 h]; Geotextil [11203] |  |
|  | 4 | **Colocacion de Roca** |  |  | 2025-07-04 | 2025-07-31 |  |  |  |  |  |
| A2790 |  | Colocación de roca en uña |  | 8d | 2025-07-04 | 2025-07-11 | A2700, A7962 SS | 17d | 0d | Excavator [64 h]; HH [64 h]; Roca [3615.18 m3] | 4,480 |
| A2800 |  | Colocación de roca en talud |  | 20d | 2025-07-12 | 2025-07-31 | A2790, A2770 SS+2d, A2700 SS+1d, A8130 | 17d | 0d | Excavator [160 h]; HH [160 h]; Roca [3544.56 m3] | 11,200 |
|  | 5 | **Transporte** |  |  | 2025-06-14 | 2025-07-31 |  |  |  |  |  |
| A6050 |  | Transporte de material orgánico (a dmo) |  | 2d | 2025-06-14 | 2025-06-15 | A2670 SS | 94d | 0d | HH [16 h] |  |
| A6060 |  | Transporte de material excedente |  | 18d | 2025-06-16 | 2025-07-03 | A2680 SS, A6050, A6070 FF | 94d | 28d | HH [168 h] |  |
| A6100 |  | Transporte de material seleccionado para zanja |  | 1d | 2025-06-20 | 2025-06-20 | A2780 SS | 97d | 0d | HH [8 h] |  |
| A6090 |  | Transporte de material de préstamo cantera de rio (cuerpo de terraplén) |  | 5d | 2025-06-21 | 2025-06-25 | A2710 SS, A6100 | 97d | 0d | HH [40 h] |  |
| A6070 |  | Transporte de material de prestamo (afirmado) |  | 5d | 2025-06-26 | 2025-06-30 | A2710 SS, A6090 | 97d | 3d | HH [40 h] |  |
| A6080 |  | Transporte de roca |  | 28d | 2025-07-04 | 2025-07-31 | A2790 SS | 66d | 0d | HH [224 h] |  |

| ID | WBS | Activity | Type | Duration | Start | Finish | Predecessors | Total float | Free float | Resources | Cost |
| --- | --- | --- | --- | --- | --- | --- | --- | --- | --- | --- | --- |
|  | 12 | **I-10-PT** |  |  | 2025-08-01 | 2025-09-18 |  |  |  |  |  |
| A7580 |  | Inicio I-10-PT-92+923.32 - Entrega de terreno liberado | milestone | 0d | 2025-08-01 | 2025-08-01 | A2800 | 17d | 0d |  |  |
| A7590 |  | Fin I-10-PT-92+923.32 - Entrega de terreno liberado | milestone | 0d | 2025-09-18 | 2025-09-18 | A2660 FF, A6640 FF, A6620 FF | 17d | 3d |  |  |
|  | 1 | **DIQUE** |  |  | 2025-08-01 | 2025-09-18 |  |  |  |  |  |
|  | 1 | **Excavaciones** |  |  | 2025-08-01 | 2025-08-20 |  |  |  |  |  |
| A2550 |  | Desbroce |  | 0d | 2025-08-01 | 2025-08-01 | A7580 SS | 17d | 0d | Excavator; HH |  |
| A2560 |  | Excavación de cimentación |  | 10d | 2025-08-01 | 2025-08-10 | A2550 | 17d | 0d | Excavator [80 h]; HH [80 h] | 5,600 |
| A2570 |  | Perfilado y conformación de plataforma de fundación |  | 7d | 2025-08-03 | 2025-08-09 | A2560 SS+2d | 18d | 1d | HH [56 h] |  |
| A2580 |  | Excavacion de uña |  | 10d | 2025-08-11 | 2025-08-20 | A2560, A2570 | 17d | 0d | Excavator [80 h]; HH [80 h] | 5,600 |
|  | 2 | **Rellenos** |  |  | 2025-08-06 | 2025-08-11 |  |  |  |  |  |
| A2590 |  | Relleno con material granular (incluye extracción de material, zarandeo y / combinación de material) |  | 1d | 2025-08-06 | 2025-08-06 | A2560 SS+5d | 29d | 0d | HH [8 h]; MONEDA [249.07] | 249.07 |
| A2600 |  | Perfilado de talud del dique |  | 1d | 2025-08-07 | 2025-08-07 | A2590 | 29d | 0d | HH [8 h] |  |
| A2610 |  | Relleno con material seleccionado (incluye extracción de material, / zarandeo y combinación de material) en sobreex |  | 2d | 2025-08-08 | 2025-08-09 | A2590, A2600 | 29d | 0d | HH [16 h]; Cerco [446.9] |  |
| A2620 |  | Relleno mejorado con cemento |  | 2d | 2025-08-10 | 2025-08-11 | A2610 | 29d | 0d | HH [16 h]; Relleno mejorado con Cemento [219] |  |
|  | 3 | **Geotextiles** |  |  | 2025-08-12 | 2025-08-21 |  |  |  |  |  |
| A2640 |  | Zanja de anclaje |  | 1d | 2025-08-12 | 2025-08-12 | A2620 | 29d | 0d | HH [8 h] |  |
| A2630 |  | Instalación de geotextil 400 gr/m2 |  | 9d | 2025-08-13 | 2025-08-21 | A2640 | 29d | 12d | HH [72 h]; Geotextil [4413.56] |  |
|  | 4 | **Colocacion de Roca** |  |  | 2025-08-21 | 2025-09-18 |  |  |  |  |  |
| A2650 |  | Colocación de roca en uña |  | 13d | 2025-08-21 | 2025-09-02 | A2580, A7962 SS | 17d | 0d | Excavator [104 h]; HH [104 h]; Roca [3345.78 m3] | 7,280 |
| A2660 |  | Colocación de roca en talud |  | 16d | 2025-09-03 | 2025-09-18 | A2650, A2580, A2630, A8120 | 17d | 0d | Excavator [128 h]; HH [128 h]; Roca [2280.75 m3] | 8,960 |
|  | 5 | **Transporte** |  |  | 2025-08-01 | 2025-09-18 |  |  |  |  |  |
| A6590 |  | Transporte de material orgánico (a dmo) |  | 1d | 2025-08-01 | 2025-08-01 | A2550 SS, A6560 | 36d | 0d | HH [8 h] |  |
| A6600 |  | Transporte de material excedente |  | 19d | 2025-08-02 | 2025-08-20 | A2560 SS, A6590 | 36d | 19d | HH [144 h] |  |
| A6610 |  | Transporte de material de prestamo (afirmado) |  | 1d | 2025-08-06 | 2025-08-06 | A2590 SS | 57d | 1d | HH [8 h] |  |
| A6630 |  | Transporte de material de préstamo cantera de rio (cuerpo de terraplén) |  | 2d | 2025-08-08 | 2025-08-09 | A2610 SS, A6610 | 56d | 2d | HH [16 h] |  |
| A6640 |  | Transporte de material seleccionado para zanja |  | 1d | 2025-08-12 | 2025-08-12 | A2640 SS, A6630 | 54d | 37d | HH [8 h] |  |
| A6620 |  | Transporte de roca |  | 29d | 2025-08-21 | 2025-09-18 | A2650 SS, A6600 SS | 17d | 0d | HH [216 h] |  |

| ID | WBS | Activity | Type | Duration | Start | Finish | Predecessors | Total float | Free float | Resources | Cost |
| --- | --- | --- | --- | --- | --- | --- | --- | --- | --- | --- | --- |
|  | 21 | **I-05-PT** |  |  | 2025-05-01 | 2025-07-08 |  |  |  |  |  |
| A7700 |  | Inicio I-05-PT-111+569.71 - Entrega de terreno liberado | milestone | 0d | 2025-05-01 | 2025-05-01 | A5370 | 24d | 0d |  |  |
| A7710 |  | Fin I-05-PT-111+569.71 - Entrega de terreno liberado | milestone | 0d | 2025-05-07 | 2025-05-07 | A3580 FF | 151d | 137d |  |  |
|  | 1 | **DIQUE** |  |  | 2025-05-01 | 2025-07-08 |  |  |  |  |  |
|  | 1 | **Excavaciones** |  |  | 2025-05-01 | 2025-05-18 |  |  |  |  |  |
| A3540 |  | Desbroce |  | 1d | 2025-05-01 | 2025-05-01 | A7700 SS | 24d | 0d | Excavator [8 h]; HH [8 h] | 560 |
| A3550 |  | Excavación de cimentación |  | 5d | 2025-05-01 | 2025-05-05 | A3540 SS | 24d | 0d | Excavator [40 h]; HH [40 h] | 2,800 |
| A3560 |  | Perfilado y conformación de plataforma de fundación |  | 4d | 2025-05-01 | 2025-05-04 | A3550 SS | 25d | 1d | HH [32 h] |  |
| A3570 |  | Excavación de uña |  | 13d | 2025-05-06 | 2025-05-18 | A3550, A3560 | 24d | 0d | Excavator [104 h]; HH [104 h] | 7,280 |
|  | 2 | **Rellenos** |  |  | 2025-05-06 | 2025-05-10 |  |  |  |  |  |
| A3580 |  | Relleno con material granular (incluye extracción de material, zarandeo y / combinación de material) |  | 2d | 2025-05-06 | 2025-05-07 | A3550 | 42d | 0d | HH [16 h]; MONEDA [976.54] | 976.54 |
| A3590 |  | Relleno mejorado con cemento |  | 3d | 2025-05-08 | 2025-05-10 | A3580 | 42d | 0d | HH [24 h]; Relleno mejorado con Cemento [304] |  |
|  | 3 | **Geotextil** |  |  | 2025-05-08 | 2025-05-23 |  |  |  |  |  |
| A3610 |  | Zanja de anclaje |  | 3d | 2025-05-08 | 2025-05-10 | A3580 | 42d | 0d | HH [24 h] |  |
| A3600 |  | Instalación de geotextil 400 gr/m2 |  | 13d | 2025-05-11 | 2025-05-23 | A3610, A3590 | 42d | 18d | HH [104 h]; Geotextil [13394.3] |  |
|  | 4 | **Colocacion de Roca** |  |  | 2025-05-19 | 2025-07-08 |  |  |  |  |  |
| A3620 |  | Colocación de roca en uña |  | 23d | 2025-05-19 | 2025-06-10 | A3570, A7962 SS | 24d | 0d | Excavator [184 h]; HH [176 h]; Roca [5424.11 m3] | 12,880 |
| A3630 |  | Colocación de roca en talud |  | 28d | 2025-06-11 | 2025-07-08 | A3620, A3600, A8240 | 24d | 0d | Excavator [200 h]; HH [200 h]; Roca [4425.74 m3] | 14,000 |
|  | 5 | **Transporte** |  |  | 2025-05-01 | 2025-07-08 |  |  |  |  |  |
| A6950 |  | Transporte de material orgánico (a dmo) |  | 1d | 2025-05-01 | 2025-05-01 | A3540 SS | 88d | 0d | HH [8 h] |  |
| A6960 |  | Transporte de material excedente |  | 18d | 2025-05-01 | 2025-05-18 | A3550 SS, A6950 SS | 88d | 0d | HH [144 h] |  |
| A6970 |  | Transporte de material de prestamo (afirmado) |  | 2d | 2025-05-06 | 2025-05-07 | A3580 SS | 94d | 0d | HH [16 h] |  |
| A6990 |  | Transporte de material de préstamo cantera de rio (cuerpo de terraplén) |  | 2d | 2025-05-08 | 2025-05-09 | A3580 SS, A6970 | 94d | 0d | HH [16 h] |  |
| A7000 |  | Transporte de material seleccionado para zanja |  | 3d | 2025-05-10 | 2025-05-12 | A3610 SS, A6990 | 94d | 6d | HH [24 h] |  |
| A6980 |  | Transporte de roca |  | 51d | 2025-05-19 | 2025-07-08 | A3620 SS, A6960, A7000 | 88d | 0d | HH [384 h] |  |

| ID | WBS | Activity | Type | Duration | Start | Finish | Predecessors | Total float | Free float | Resources | Cost |
| --- | --- | --- | --- | --- | --- | --- | --- | --- | --- | --- | --- |
|  | 23 | **I-04-2-DI** |  |  | 2025-07-09 | 2025-07-27 |  |  |  |  |  |
| A7720 |  | Inicio I-04-2-DI-113+202.93 - Entrega de terreno liberado | milestone | 0d | 2025-07-09 | 2025-07-09 | A3630 | 24d | 0d |  |  |
| A7730 |  | Fin I-04-2-DI-113+202.93 - Entrega de terreno liberado | milestone | 0d | 2025-07-27 | 2025-07-27 | A3880 FF | 70d | 56d |  |  |
|  | 1 | **DIQUE** |  |  | 2025-07-09 | 2025-07-27 |  |  |  |  |  |
|  | 1 | **Excavaciones** |  |  | 2025-07-09 | 2025-07-17 |  |  |  |  |  |
| A3790 |  | Desbroce |  | 1d | 2025-07-09 | 2025-07-09 | A7720 SS | 24d | 0d | Excavator [8 h]; HH [8 h] | 560 |
| A3800 |  | Excavación de cimentación |  | 5d | 2025-07-09 | 2025-07-13 | A3790 SS | 24d | 0d | Excavator [40 h]; HH [40 h] | 2,800 |
| A3810 |  | Perfilado y conformación de plataforma de fundación |  | 3d | 2025-07-11 | 2025-07-13 | A3800 SS+2d | 27d | 0d | HH [24 h] |  |
| A3820 |  | Excavación de uña |  | 4d | 2025-07-14 | 2025-07-17 | A3800, A3810 | 27d | 3d | Excavator [32 h]; HH [32 h] | 2,240 |
|  | 2 | **Rellenos** |  |  | 2025-07-11 | 2025-07-13 |  |  |  |  |  |
| A3830 |  | Relleno con material granular (incluye extracción de material, zarandeo y / combinación de material) |  | 1d | 2025-07-11 | 2025-07-11 | A3800 SS+2d | 28d | 0d | HH [8 h]; MONEDA [79.37] | 79.37 |
| A3840 |  | Relleno mejorado con cemento |  | 2d | 2025-07-12 | 2025-07-13 | A3830 | 31d | 7d | HH [16 h]; Relleno mejorado con Cemento [164] |  |
|  | 3 | **Geotextil** |  |  | 2025-07-12 | 2025-07-16 |  |  |  |  |  |
| A3850 |  | Instalación de geotextil 400 gr/m2 |  | 5d | 2025-07-12 | 2025-07-16 | A3860 SS | 28d | 4d | HH [32 h]; Geotextil [2187.95] |  |
| A3860 |  | Zanja de anclaje |  | 1d | 2025-07-12 | 2025-07-12 | A3830 | 28d | 0d | HH [8 h] |  |
|  | 4 | **Colocacion de Roca** |  |  | 2025-07-14 | 2025-07-27 |  |  |  |  |  |
| A3870 |  | Colocación de roca en uña |  | 7d | 2025-07-14 | 2025-07-20 | A3800, A7962 SS | 24d | 0d | Excavator [56 h]; HH [56 h]; Roca [1685.88 m3] | 3,920 |
| A3880 |  | Colocación de roca en talud |  | 7d | 2025-07-21 | 2025-07-27 | A3870, A3820, A3840, A3850, A8230 | 24d | 0d | Excavator [48 h]; HH [48 h]; Roca [1088.12 m3] | 3,360 |
|  | 5 | **Transporte** |  |  | 2025-07-09 | 2025-07-27 |  |  |  |  |  |
| A7010 |  | Transporte de material orgánico (a dmo) |  | 1d | 2025-07-09 | 2025-07-09 | A3790 SS, A6980 | 88d |  | HH [8 h] |  |
| A7020 |  | Transporte de material excedente |  | 9d | 2025-07-09 | 2025-07-17 | A3800 SS | 55d | 10d | HH [72 h] |  |
| A7030 |  | Transporte de material de prestamo (afirmado) |  | 1d | 2025-07-11 | 2025-07-11 | A3830 SS | 46d | 0d | HH [8 h] |  |
| A7050 |  | Transporte de material de préstamo cantera de rio (cuerpo de terraplén) |  | 2d | 2025-07-12 | 2025-07-13 | A3830 SS, A7030 | 46d | 0d | HH [16 h] |  |
| A7060 |  | Transporte de material seleccionado para zanja |  | 1d | 2025-07-12 | 2025-07-12 | A3860 SS, A7050 SS | 46d | 1d | HH [8 h] |  |
| A7040 |  | Transporte de roca |  | 14d | 2025-07-14 | 2025-07-27 | A3870 SS, A7060 | 45d | 0d | HH [104 h] |  |

| ID | WBS | Activity | Type | Duration | Start | Finish | Predecessors | Total float | Free float | Resources | Cost |
| --- | --- | --- | --- | --- | --- | --- | --- | --- | --- | --- | --- |
|  | 24 | **I-03-PT- Muro** |  |  | 2025-07-28 | 2025-08-15 |  |  |  |  |  |
| A7740 |  | Inicio I-03-PT-131+362.06 - Entrega de terreno liberado | milestone | 0d | 2025-07-28 | 2025-07-28 | A3880 | 24d | 0d |  |  |
| A7750 |  | Fin I-03-PT-131+362.06 - Entrega de terreno liberado | milestone | 0d | 2025-08-15 | 2025-08-15 | A5360 FF | 51d |  |  |  |
|  | 1 | **DIQUE** |  |  | 2025-07-28 | 2025-08-15 |  |  |  |  |  |
|  | 1 | **Excavaciones** |  |  | 2025-07-28 | 2025-07-29 |  |  |  |  |  |
| A3890 |  | Desbroce |  | 1d | 2025-07-28 | 2025-07-28 | A7740 SS | 24d | 0d | Excavator [8 h]; HH [8 h] | 560 |
| A3900 |  | Excavación de cimentación |  | 1d | 2025-07-28 | 2025-07-28 | A3890 SS | 24d | 0d | Excavator [8 h]; HH [8 h] | 560 |
| A3910 |  | Excavación de uña |  | 1d | 2025-07-29 | 2025-07-29 | A3900 | 40d | 16d | Excavator [8 h]; HH [8 h] | 560 |
|  | 2 | **Rellenos** |  |  | 2025-08-15 | 2025-08-15 |  |  |  |  |  |
| A3920 |  | Relleno con material seleccionado (incluye extracción de material, / zarandeo y combinación de material) en sobreex |  | 1d | 2025-08-15 | 2025-08-15 | A5190, A5230 | 29d | 0d | HH [8 h]; Cerco [91.47] |  |
|  | 4 | **Colocacion de Roca** |  |  | 2025-08-15 | 2025-08-15 |  |  |  |  |  |
| A5360 |  | Colocación de roca en uña |  | 1d | 2025-08-15 | 2025-08-15 | A5190, A3910, A7961 SS | 24d | 0d | Excavator [8 h]; HH [8 h]; Roca [42 m3] | 560 |
|  | 5 | **Transporte** |  |  | 2025-07-28 | 2025-08-15 |  |  |  |  |  |
| A7070 |  | Transporte de material orgánico (a dmo) |  | 1d | 2025-07-28 | 2025-07-28 | A3890 SS, A7020, A7040 | 45d | 0d | HH [8 h] |  |
| A7080 |  | Transporte de material excedente |  | 1d | 2025-07-29 | 2025-07-29 | A3900 SS, A7070 | 45d | 16d | HH [8 h] |  |
| A7090 |  | Transporte de material de prestamo (afirmado) |  | 1d | 2025-08-15 | 2025-08-15 | A3920 SS, A7080 | 29d | 0d | HH [8 h] |  |
| A7100 |  | Transporte de roca |  | 1d | 2025-08-15 | 2025-08-15 | A5360 SS, A7090 SS | 29d | 0d | HH [8 h] |  |
|  | 3 | **MURO** |  |  | 2025-07-29 | 2025-08-14 |  |  |  |  |  |
| A5130 |  | Concreto Ciclopeo (f'c=280 kg/cm2) + 30%PG. |  | 6d | 2025-07-29 | 2025-08-03 | A3900 | 24d | 0d | HH [48 h]; CONCRETO PREMEZCLADO F'C=280 kg/cm2 CON CEMENTO T-I [108] |  |
| A5160 |  | Encofrado y desencofrado caravista |  | 5d | 2025-07-30 | 2025-08-03 | A5130 SS+1d | 30d | 0d | HH [40 h] |  |
| A5170 |  | Encofrado y desencofrado cara oculta |  | 6d | 2025-07-30 | 2025-08-04 | A5160 SS | 30d | 6d | HH [48 h]; MADERA TORNILLO [663 und] |  |
| A5180 |  | Acero de refuerzo f'y=4200kg/cm2 |  | 7d | 2025-08-04 | 2025-08-10 | A5130 | 24d | 0d | HH [56 h]; acero [26281] |  |
| A5220 |  | Tubo pvc - d=4'' |  | 1d | 2025-08-04 | 2025-08-04 | A5130 | 31d | 0d | HH [8 h] |  |
| A5210 |  | Tubo pvc - d=6'' |  | 1d | 2025-08-05 | 2025-08-05 | A5130, A5220 | 31d | 0d | HH [8 h] |  |
| A5200 |  | Geocompuesto de drenaje |  | 2d | 2025-08-06 | 2025-08-07 | A5130, A5210 | 31d | 7d | HH [16 h] |  |
| A5150 |  | Concreto clase c (f'c=280 kg/cm2) premezclado - muros de contencion |  | 2d | 2025-08-11 | 2025-08-12 | A5130 FS+1d, A5170, A5180 | 24d | 0d | HH [16 h]; CONCRETO PREMEZCLADO F'C=280 kg/cm2 CON CEMENTO T-I [9.69]; PIEDRA CHANCADA [5.45]; ARENA GRUESA [5.28]; CEMENTO PORTLAND TIPO I (42.5 kg) [88.47] |  |
| A5190 |  | Pintura bituminosa |  | 2d | 2025-08-13 | 2025-08-14 | A5150, A5200 SS | 24d | 0d | HH [27.01 h]; PINTURA ASFALTICA [182] |  |
| A5230 |  | Junta de dilatación |  | 2d | 2025-08-13 | 2025-08-14 | A5150 | 29d | 0d | HH [16 h] |  |

| ID | WBS | Activity | Type | Duration | Start | Finish | Predecessors | Total float | Free float | Resources | Cost |
| --- | --- | --- | --- | --- | --- | --- | --- | --- | --- | --- | --- |
|  | 25 | **D-01-DI** |  |  | 2025-08-16 | 2025-09-11 |  |  |  |  |  |
| A7760 |  | Inicio D-01-DI-131+584.72 - Entrega de terreno liberado | milestone | 0d | 2025-08-16 | 2025-08-16 | A5360 | 24d | 0d |  |  |
| A7770 |  | Fin D-01-DI-131+584.72 - Entrega de terreno liberado | milestone | 0d | 2025-09-11 | 2025-09-11 | A4160 FF, A7160 FF | 24d | 10d |  |  |
|  | 1 | **DIQUE** |  |  | 2025-08-16 | 2025-09-11 |  |  |  |  |  |
|  | 1 | **Excavaciones** |  |  | 2025-08-16 | 2025-09-06 |  |  |  |  |  |
| A4040 |  | Desbroce |  | 1d | 2025-08-16 | 2025-08-16 | A7760 SS | 24d | 0d | Excavator [8 h]; HH [8 h] | 560 |
| A4050 |  | Excavación de cimentación |  | 14d | 2025-08-16 | 2025-08-29 | A4040 SS | 24d | 0d | Excavator [112 h]; HH [112 h] | 7,840 |
| A4060 |  | Perfilado y conformación de plataforma de fundación |  | 8d | 2025-08-22 | 2025-08-29 | A4050 SS+6d | 26d | 0d | HH [64 h] |  |
| A4070 |  | Excavación de uña |  | 8d | 2025-08-30 | 2025-09-06 | A4050, A4060 | 26d | 2d | Excavator [64 h]; HH [64 h] | 4,480 |
|  | 2 | **Rellenos** |  |  | 2025-08-21 | 2025-08-30 |  |  |  |  |  |
| A4080 |  | Relleno con material granular (incluye extracción de material, zarandeo y / combinación de material) |  | 6d | 2025-08-21 | 2025-08-26 | A4050 SS+5d | 25d | 0d | HH [48 h]; MONEDA [3572.24] | 3,572.24 |
| A4110 |  | Relleno con material seleccionado (incluye extracción de material, / zarandeo y combinación de material) en sobreex |  | 4d | 2025-08-22 | 2025-08-25 | A4080 SS+1d | 25d | 0d | HH [32 h]; Cerco [879.66] |  |
| A4120 |  | Grava para drenaje |  | 6d | 2025-08-23 | 2025-08-28 | A4110 SS+1d | 25d | 0d | HH [48 h]; Grava para drenaje [432] |  |
| A4100 |  | Perfilado de talud del dique |  | 3d | 2025-08-25 | 2025-08-27 | A4080 SS+4d | 26d | 1d | HH [24 h] |  |
| A4090 |  | Relleno sin compactar |  | 1d | 2025-08-29 | 2025-08-29 | A4120, A4100 | 25d | 0d | HH [8 h] |  |
| A4130 |  | Relleno mejorado con cemento |  | 1d | 2025-08-30 | 2025-08-30 | A4080, A4090 | 25d | 1d | HH [8 h]; Relleno mejorado con Cemento [303.24] |  |
|  | 3 | **Geotextil** |  |  | 2025-08-21 | 2025-08-30 |  |  |  |  |  |
| A4140 |  | Instalación de geotextil 400 gr/m2 |  | 10d | 2025-08-21 | 2025-08-30 | A4080 SS | 25d | 1d | HH [80 h]; Geotextil [5059.04] |  |
|  | 4 | **Colocacion de Roca** |  |  | 2025-08-24 | 2025-09-11 |  |  |  |  |  |
| A4150 |  | Colocación de roca en uña |  | 8d | 2025-08-24 | 2025-08-31 | A4050 SS+8d, A7961 SS | 24d | 0d | Excavator [56 h]; HH [56 h]; Roca [3598.51 m3] | 3,920 |
| A4160 |  | Colocación de roca en talud |  | 11d | 2025-09-01 | 2025-09-11 | A4150, A4070 SS, A4130, A4140, A8220 | 24d | 0d | Excavator [144 h]; HH [144 h]; Roca [3318.72 m3] | 10,080 |
|  | 5 | **Transporte** |  |  | 2025-08-16 | 2025-09-11 |  |  |  |  |  |
| A7130 |  | Transporte de material orgánico (a dmo) |  | 1d | 2025-08-16 | 2025-08-16 | A4040 SS, A7100 | 29d | 0d | HH [8 h] |  |
| A7140 |  | Transporte de material excedente |  | 22d | 2025-08-16 | 2025-09-06 | A4050 SS, A7130 SS | 29d | 8d | HH [176 h] |  |
| A7150 |  | Transporte de material de prestamo (afirmado) |  | 7d | 2025-08-21 | 2025-08-27 | A4080 SS | 27d | 1d | HH [56 h] |  |
| A7170 |  | Transporte de material de préstamo cantera de rio (cuerpo de terraplén) |  | 5d | 2025-08-22 | 2025-08-26 | A4110 SS, A7150 SS | 26d | 2d | HH [40 h] |  |
| A7160 |  | Transporte de roca |  | 19d | 2025-08-24 | 2025-09-11 | A4150 SS, A7140 SS, A7170 SS | 24d | 0d | HH [216 h] |  |

| ID | WBS | Activity | Type | Duration | Start | Finish | Predecessors | Total float | Free float | Resources | Cost |
| --- | --- | --- | --- | --- | --- | --- | --- | --- | --- | --- | --- |
|  | 26 | **I-02-DI - Muro** |  |  | 2025-05-01 | 2025-07-05 |  |  |  |  |  |
| A7560 |  | Inicio I-02-DI-131+367.15 - Entrega de terreno liberado | milestone | 0d | 2025-05-01 | 2025-05-01 | A5370 | 12d | 0d |  |  |
| A7570 |  | Fin I-02-DI-131+367.15 - Entrega de terreno liberado | milestone | 0d | 2025-06-16 | 2025-06-16 | A4290 FF, A4310 FF, A8190 FF | 111d |  |  |  |
|  | 1 | **DIQUE** |  |  | 2025-05-01 | 2025-06-16 |  |  |  |  |  |
|  | 1 | **Excavaciones** |  |  | 2025-05-01 | 2025-05-24 |  |  |  |  |  |
| A4170 |  | Desbroce |  | 1d | 2025-05-01 | 2025-05-01 | A7560 SS | 12d | 0d | Excavator [8 h]; HH [8 h] | 560 |
| A4180 |  | Excavacion de cimentación |  | 11d | 2025-05-01 | 2025-05-11 | A4170 SS | 12d | 0d | Excavator [88 h]; HH [88 h] | 6,160 |
| A4190 |  | Perfilado y conformación de plataforma de fundación |  | 8d | 2025-05-04 | 2025-05-11 | A4180 SS+3d | 12d | 0d | HH [64 h] |  |
| A4200 |  | Excavacion de uña |  | 13d | 2025-05-12 | 2025-05-24 | A4180, A4190 | 12d | 0d | Excavator [104 h]; HH [104 h] | 7,280 |
|  | 2 | **Rellenos** |  |  | 2025-05-12 | 2025-06-06 |  |  |  |  |  |
| A4220 |  | Perfilado de talud del dique |  | 1d | 2025-05-12 | 2025-05-12 | A4180 | 19d | 0d | HH [8 h] |  |
| A4230 |  | Relleno con material seleccionado (incluye extracción de material, / zarandeo y combinación de material) en sobreex |  | 1d | 2025-05-13 | 2025-05-13 | A4220 | 19d | 0d | HH [8 h]; Cerco [224] |  |
| A4240 |  | Relleno mejorado con cemento |  | 1d | 2025-05-14 | 2025-05-14 | A4230 | 22d | 3d | HH [8 h]; Relleno mejorado con Cemento [106.16] |  |
| A4250 |  | Relleno estructural |  | 9d | 2025-05-29 | 2025-06-06 | A5340, A5300, A4230 | 111d | 0d | HH [72 h]; Relleno estructural [3048] |  |
|  | 3 | **Geotextil** |  |  | 2025-05-14 | 2025-05-28 |  |  |  |  |  |
| A4270 |  | Zanja de anclaje |  | 4d | 2025-05-14 | 2025-05-17 | A4230 | 19d | 0d | HH [24 h] |  |
| A4260 |  | Instalación de geotextil 400 gr/m2 |  | 11d | 2025-05-18 | 2025-05-28 | A4270, A4240 | 19d | 7d | HH [168 h]; Geotextil [10450.1] |  |
|  | 4 | **Colocacion de Roca** |  |  | 2025-05-25 | 2025-06-16 |  |  |  |  |  |
| A4280 |  | Colocación de roca en uña |  | 11d | 2025-05-25 | 2025-06-04 | A4200, A5300, A7961 SS | 12d | 0d | Excavator [104 h]; HH [104 h]; Roca [5210.1 m3] | 7,280 |
| A4290 |  | Colocación de roca en talud |  | 12d | 2025-06-05 | 2025-06-16 | A4280, A4260 | 12d | 0d | Excavator [128 h]; HH [128 h]; Roca [2801.02 m3] | 8,960 |
| A4300 |  | Concreto f'c=210kg/cm2 para recebado |  | 8d | 2025-06-07 | 2025-06-14 | A4290 SS, A4250 | 111d | 0d | HH [64 h] |  |
| A4310 |  | Colocación de roca en corona |  | 2d | 2025-06-15 | 2025-06-16 | A4300 | 111d | 0d | Excavator [16 h]; HH [16 h]; Roca [156 m3] | 1,120 |
|  | 5 | **Transporte** |  |  | 2025-05-01 | 2025-06-16 |  |  |  |  |  |
| A6530 |  | Transporte de material orgánico (a dmo) |  | 1d | 2025-05-01 | 2025-05-01 | A4170 SS | 81d | 0d | HH [8 h] |  |
| A6540 |  | Transporte de material excedente |  | 23d | 2025-05-02 | 2025-05-24 | A4180 SS, A6530 | 81d | 0d | HH [192 h] |  |
| A6570 |  | Transporte de material de préstamo cantera de rio (cuerpo de terraplén) |  | 4d | 2025-05-13 | 2025-05-16 | A4230 SS | 86d | 0d | HH [8 h] |  |
| A6580 |  | Transporte de material seleccionado para zanja |  | 3d | 2025-05-17 | 2025-05-19 | A4270 SS, A6570 | 86d | 5d | HH [24 h] |  |
| A6560 |  | Transporte de roca |  | 23d | 2025-05-25 | 2025-06-16 | A4280 SS, A6540, A6580 | 81d | 45d | HH [224 h] |  |

| ID | WBS | Activity | Type | Duration | Start | Finish | Predecessors | Total float | Free float | Resources | Cost |
| --- | --- | --- | --- | --- | --- | --- | --- | --- | --- | --- | --- |
|  | 5 | **MURO** |  |  | 2025-05-01 | 2025-05-28 |  |  |  |  |  |
| A5240 |  | Concreto de nivelacion (f'c=100 kg/cm2) |  | 8d | 2025-05-01 | 2025-05-08 | A4180 SS | 14d | 0d | HH [64 h]; CONCRETO PREMEZCLADO F'C=100 kg/cm2 CON CEMENTO T-I [144] |  |
| A5270 |  | Encofrado y desencofrado caravista |  | 15d | 2025-05-03 | 2025-05-17 | A5240 SS+2d | 16d | 0d | HH [120 h] |  |
| A5330 |  | Tubo pvc - d=4'' |  | 2d | 2025-05-03 | 2025-05-04 | A5240 SS+2d | 18d | 4d | HH [16 h] |  |
| A5280 |  | Encofrado y desencofrado cara oculta |  | 17d | 2025-05-05 | 2025-05-21 | A5270 SS+2d | 16d | 0d | HH [136 h]; MADERA TORNILLO [5150 und] |  |
| A5290 |  | Acero de refuerzo f'y=4200kg/cm2 |  | 18d | 2025-05-05 | 2025-05-22 | A5280 SS | 16d | 0d | HH [144 h]; acero [105853] |  |
| A5250 |  | Concreto clase c (f'c=280 kg/cm2) premezclado - cimientos reforzados |  | 11d | 2025-05-07 | 2025-05-17 | A5290 SS+2d | 16d | 0d | HH [88 h]; CONCRETO PREMEZCLADO F'C=280 kg/cm2 CON CEMENTO T-I [642]; PIEDRA CHANCADA [674.64]; ARENA GRUESA [652.72]; CEMENTO PORTLAND TIPO I (42.5 kg) [10945.4] |  |
| A5320 |  | Tubo pvc - d=6'' |  | 4d | 2025-05-09 | 2025-05-12 | A5240, A5330 | 14d | 0d | HH [32 h] |  |
| A5310 |  | Geocompuesto de drenaje |  | 5d | 2025-05-13 | 2025-05-17 | A5240, A5320 | 14d | 0d | HH [40 h] |  |
| A5260 |  | Concreto clase c (f'c=280 kg/cm2) premezclado - muros de contencion |  | 11d | 2025-05-14 | 2025-05-24 | A5250 SS+7d | 16d | 0d | HH [88 h]; CONCRETO PREMEZCLADO F'C=280 kg/cm2 CON CEMENTO T-I [427] |  |
| A5300 |  | Pintura bituminosa |  | 5d | 2025-05-18 | 2025-05-22 | A5260 SS, A5310 | 14d | 2d | HH [1064.11 h]; PINTURA ASFALTICA [1218] |  |
| A5340 |  | Junta de dilatación |  | 4d | 2025-05-25 | 2025-05-28 | A5260 | 16d | 0d | HH [32 h] |  |
|  | 4 | **RAMPA DESEMBARCO CANOTAJE** |  |  | 2025-05-17 | 2025-07-05 |  |  |  |  |  |
| A5470 |  | Rampa de desembarco canotaje |  | 50d | 2025-05-17 | 2025-07-05 | A4170 FS+15d | 92d |  | HH [3440 h] |  |
|  | 22 | **I-04-1-DI- Muro** |  |  | 2025-06-13 | 2025-07-23 |  |  |  |  |  |
| A7640 |  | Inicio I-04-1-DI-113+105.55 - Entrega de terreno liberado | milestone | 0d | 2025-06-27 | 2025-06-27 | A4290 FS+10d | 12d | 0d |  |  |
| A7650 |  | Fin I-04-1-DI-113+105.55 - Entrega de terreno liberado | milestone | 0d | 2025-07-23 | 2025-07-23 | A5350 FF, A3660 FF | 74d |  |  |  |
|  | 1 | **DIQUE** |  |  | 2025-06-27 | 2025-07-23 |  |  |  |  |  |
|  | 1 | **Excavaciones** |  |  | 2025-06-27 | 2025-07-12 |  |  |  |  |  |
| A3640 |  | Desbroce |  | 4d | 2025-06-27 | 2025-06-30 | A7640 SS | 12d | 0d | Excavator [32 h]; HH [32 h] | 2,240 |
| A3650 |  | Excavación de cimentación |  | 16d | 2025-06-27 | 2025-07-12 | A3640 SS | 15d | 0d | Excavator [128 h]; HH [128 h] | 8,960 |
|  | 2 | **Rellenos** |  |  | 2025-07-04 | 2025-07-15 |  |  |  |  |  |
| A3660 |  | Relleno estructural |  | 12d | 2025-07-04 | 2025-07-15 | A5120 SS+2d, A5080 SS+2d | 82d | 8d | HH [96 h]; Relleno estructural [3882] |  |
|  | 4 | **Colocacion de Roca** |  |  | 2025-07-16 | 2025-07-23 |  |  |  |  |  |
| A5350 |  | Colocacion de roca en uña |  | 8d | 2025-07-16 | 2025-07-23 | A5080, A5090, A3650, A8180, A8170, A7962 SS | 12d | 0d | Excavator [64 h]; HH [64 h]; Roca [1448.1 m3] | 4,480 |

| ID | WBS | Activity | Type | Duration | Start | Finish | Predecessors | Total float | Free float | Resources | Cost |
| --- | --- | --- | --- | --- | --- | --- | --- | --- | --- | --- | --- |
|  | 5 | **Transporte** |  |  | 2025-06-27 | 2025-07-23 |  |  |  |  |  |
| A6770 |  | Transporte de material orgánico (a dmo) |  | 1d | 2025-06-27 | 2025-06-27 | A3640 SS | 58d | 0d | HH [8 h] |  |
| A6780 |  | Transporte de material excedente |  | 16d | 2025-06-27 | 2025-07-12 | A3650 SS, A6770 SS | 58d | 3d | HH [104 h] |  |
| A6800 |  | Transporte de roca |  | 8d | 2025-07-16 | 2025-07-23 | A5350 SS, A6780 | 55d | 0d | HH [56 h] |  |
|  | 3 | **MURO** |  |  | 2025-06-13 | 2025-07-11 |  |  |  |  |  |
| A5020 |  | Concreto de nivelacion (f'c=100 kg/cm2) |  | 5d | 2025-06-13 | 2025-06-17 | A5340 FS+15d | 16d | 0d | HH [40 h]; CONCRETO PREMEZCLADO F'C=100 kg/cm2 CON CEMENTO T-I [90] |  |
| A5050 |  | Encofrado y desencofrado caravista |  | 12d | 2025-06-14 | 2025-06-25 | A5020 SS+1d | 94d | 0d | HH [96 h] |  |
| A5030 |  | Concreto clase c (f'c=280 kg/cm2) premezclado - cimientos reforzados |  | 10d | 2025-06-18 | 2025-06-27 | A5020 | 19d | 0d | HH [80 h]; CONCRETO PREMEZCLADO F'C=280 kg/cm2 CON CEMENTO T-I [431.38]; PIEDRA CHANCADA [476.88]; ARENA GRUESA [461.38]; CEMENTO PORTLAND TIPO I (42.5 kg) [7736.84] |  |
| A5070 |  | Acero de refuerzo f'y=4200kg/cm2 |  | 14d | 2025-06-18 | 2025-07-01 | A5020 | 16d | 0d | HH [112 h]; acero [97343] |  |
| A5110 |  | Tubo pvc - d=4'' |  | 2d | 2025-06-18 | 2025-06-19 | A5020 | 24d | 0d | HH [16 h] |  |
| A5060 |  | Encofrado y desencofrado cara oculta |  | 12d | 2025-06-20 | 2025-07-01 | A5050 SS+6d | 94d | 3d | HH [96 h]; MADERA TORNILLO [3967 und] |  |
| A5100 |  | Tubo pvc - d=6'' |  | 6d | 2025-06-20 | 2025-06-25 | A5020, A5110 | 24d | 0d | HH [48 h] |  |
| A5040 |  | Concreto clase c (f'c=280 kg/cm2) premezclado - muros de contencion |  | 10d | 2025-06-23 | 2025-07-02 | A5030 SS+5d | 19d | 0d | HH [80 h]; CONCRETO PREMEZCLADO F'C=280 kg/cm2 CON CEMENTO T-I [395] |  |
| A5120 |  | Junta de dilatación |  | 7d | 2025-06-23 | 2025-06-29 | A5040 SS, A5060 SS | 91d | 9d | HH [56 h] |  |
| A5090 |  | Geocompuesto de drenaje |  | 8d | 2025-06-26 | 2025-07-03 | A5020, A5100 | 24d | 12d | HH [40 h] |  |
| A5080 |  | Pintura bituminosa |  | 10d | 2025-07-02 | 2025-07-11 | A5040 SS+6d, A5070 | 16d | 0d | HH [770.41 h]; PINTURA ASFALTICA [924] |  |
|  | 16 | **I-07-DI** |  |  | 2025-07-24 | 2025-09-13 |  |  |  |  |  |
| A7660 |  | Inicio I-07-DI-111+063.06 - Entrega de terreno liberado | milestone | 0d | 2025-07-24 | 2025-07-24 | A5350 | 12d | 0d |  |  |
| A7670 |  | Fin I-07-DI-111+063.06 - Entrega de terreno liberado | milestone | 0d | 2025-09-13 | 2025-09-13 | A3270 FF, A6880 FF | 22d | 8d |  |  |
|  | 1 | **DIQUE** |  |  | 2025-07-24 | 2025-09-13 |  |  |  |  |  |
|  | 1 | **Excavaciones** |  |  | 2025-07-24 | 2025-08-11 |  |  |  |  |  |
| A3150 |  | Desbroce |  | 2d | 2025-07-24 | 2025-07-25 | A7660 SS | 12d | 0d | Excavator [16 h]; HH [16 h] | 1,120 |
| A3160 |  | Excavación de cimentación |  | 8d | 2025-07-24 | 2025-07-31 | A3150 SS | 12d | 0d | Excavator [64 h]; HH [64 h] | 4,480 |
| A3170 |  | Perfilado y conformación de plataforma de fundación |  | 4d | 2025-07-28 | 2025-07-31 | A3160 SS+4d | 21d | 0d | HH [32 h] |  |
| A3180 |  | Excavación de uña |  | 11d | 2025-08-01 | 2025-08-11 | A3160, A3170 | 21d | 9d | Excavator [88 h]; HH [88 h] | 6,160 |

| ID | WBS | Activity | Type | Duration | Start | Finish | Predecessors | Total float | Free float | Resources | Cost |
| --- | --- | --- | --- | --- | --- | --- | --- | --- | --- | --- | --- |
|  | 2 | **Rellenos** |  |  | 2025-07-26 | 2025-08-04 |  |  |  |  |  |
| A3190 |  | Relleno con material granular (incluye extracción de material, zarandeo y / combinación de material) |  | 2d | 2025-07-26 | 2025-07-27 | A3160 SS+2d | 22d | 0d | HH [16 h]; MONEDA [2001] | 2,001 |
| A3200 |  | Perfilado de talud del dique |  | 2d | 2025-07-26 | 2025-07-27 | A3190 SS | 22d | 0d | HH [16 h] |  |
| A3210 |  | Relleno con material seleccionado (incluye extracción de material, / zarandeo y combinación de material) en sobreex |  | 6d | 2025-07-28 | 2025-08-02 | A3200 | 22d | 0d | HH [48 h]; Cerco [1075.84] |  |
| A3220 |  | Grava para drenaje |  | 1d | 2025-08-03 | 2025-08-03 | A3210 | 28d | 0d | HH [8 h]; Grava para drenaje [91.84] |  |
| A3230 |  | Relleno mejorado con cemento |  | 1d | 2025-08-04 | 2025-08-04 | A3220 | 28d | 16d | HH [8 h]; Relleno mejorado con Cemento [157.83] |  |
|  | 3 | **Geotextil** |  |  | 2025-07-28 | 2025-08-10 |  |  |  |  |  |
| A3250 |  | Zanja de anclaje |  | 3d | 2025-07-28 | 2025-07-30 | A3210 SS | 22d | 0d | HH [24 h] |  |
| A3240 |  | Instalación de geotextil 400 gr/m2 |  | 11d | 2025-07-31 | 2025-08-10 | A3250 | 22d | 10d | HH [88 h]; Geotextil [5617.85] |  |
|  | 4 | **Colocacion de Roca** |  |  | 2025-08-01 | 2025-09-13 |  |  |  |  |  |
| A3260 |  | Colocación de roca en uña |  | 20d | 2025-08-01 | 2025-08-20 | A3160, A7962 SS | 12d | 0d | Excavator [160 h]; HH [160 h]; Roca [4595.05 m3] | 11,200 |
| A3270 |  | Colocación de roca en talud |  | 24d | 2025-08-21 | 2025-09-13 | A3260, A3180, A3240, A3230, A8160 | 12d | 0d | Excavator [192 h]; HH [192 h]; Roca [3795.63 m3] | 13,440 |
|  | 5 | **Transporte** |  |  | 2025-07-24 | 2025-09-13 |  |  |  |  |  |
| A6830 |  | Transporte de material orgánico (a dmo) |  | 1d | 2025-07-24 | 2025-07-24 | A3150 SS, A6800 | 55d | 0d | HH [8 h] |  |
| A6840 |  | Transporte de material excedente |  | 18d | 2025-07-25 | 2025-08-11 | A3160 SS, A6830 | 55d | 3d | HH [152 h] |  |
| A6850 |  | Transporte de material de prestamo (afirmado) |  | 2d | 2025-07-26 | 2025-07-27 | A3190 SS | 61d | 0d | HH [16 h] |  |
| A6870 |  | Transporte de material de préstamo cantera de rio (cuerpo de terraplén) |  | 6d | 2025-07-28 | 2025-08-02 | A3210 SS, A6840 SS, A6850 | 61d | 0d | HH [48 h] |  |
| A6860 |  | Transporte de roca |  | 44d | 2025-08-01 | 2025-09-13 | A3260 SS | 22d | 40d | HH [352 h] |  |
| A6880 |  | Transporte de material seleccionado para zanja |  | 3d | 2025-08-03 | 2025-08-05 | A3250 SS, A6870 | 61d | 39d | HH [24 h] |  |
|  | 28 | **I-06-2-CM** |  |  | 2025-09-10 | 2025-09-18 |  |  |  |  |  |
| A7680 |  | Inicio I-06-2-CM-111+243.74 - Entrega de terreno liberado | milestone | 0d | 2025-09-10 | 2025-09-10 | A3270 SS+20d | 12d | 0d |  |  |
| A7690 |  | Fin I-06-2-CM-111+243.74 - Entrega de terreno liberado | milestone | 0d | 2025-09-18 | 2025-09-18 | A3530 FF, A6940 FF | 12d | 3d |  |  |
|  | 1 | **DIQUE** |  |  | 2025-09-10 | 2025-09-18 |  |  |  |  |  |
|  | 1 | **Excavaciones** |  |  | 2025-09-10 | 2025-09-13 |  |  |  |  |  |
| A3430 |  | Desbroce |  | 1d | 2025-09-10 | 2025-09-10 | A7680 SS | 12d | 0d | Excavator [8 h]; HH [8 h] | 560 |
| A3440 |  | Excavación de cimentación |  | 2d | 2025-09-10 | 2025-09-11 | A3430 SS | 12d | 0d | Excavator [8 h]; HH [8 h] | 560 |
| A3450 |  | Perfilado y conformación de plataforma de fundación |  | 1d | 2025-09-10 | 2025-09-10 | A3440 SS | 13d | 1d | HH [8 h] |  |
| A3460 |  | Excavación de uña |  | 2d | 2025-09-12 | 2025-09-13 | A3440, A3450 | 12d | 0d | Excavator [8 h]; HH [8 h] | 560 |

| ID | WBS | Activity | Type | Duration | Start | Finish | Predecessors | Total float | Free float | Resources | Cost |
| --- | --- | --- | --- | --- | --- | --- | --- | --- | --- | --- | --- |
|  | 2 | **Relleno** |  |  | 2025-09-12 | 2025-09-14 |  |  |  |  |  |
| A3470 |  | Relleno con material granular (incluye extracción de material, zarandeo y / combinación de material) |  | 1d | 2025-09-12 | 2025-09-12 | A3440 | 14d | 0d | HH [8 h]; MONEDA [262.67] | 262.67 |
| A3480 |  | Perfilado de talud del dique |  | 1d | 2025-09-13 | 2025-09-13 | A3470 | 14d | 0d | HH [8 h] |  |
| A3490 |  | Relleno mejorado con cemento |  | 1d | 2025-09-14 | 2025-09-14 | A3470, A3480 | 14d | 2d | HH [8 h]; Relleno mejorado con Cemento [28.94] |  |
|  | 3 | **Geotextil** |  |  | 2025-09-13 | 2025-09-14 |  |  |  |  |  |
| A3510 |  | Zanja de anclaje |  | 1d | 2025-09-13 | 2025-09-13 | A3470 | 14d | 0d | HH [8 h] |  |
| A3500 |  | Instalación de geotextil 400 gr/m2 |  | 1d | 2025-09-14 | 2025-09-14 | A3510 | 14d | 2d | HH [8 h]; Geotextil [802.28] |  |
|  | 4 | **Colocacion de Roca** |  |  | 2025-09-14 | 2025-09-18 |  |  |  |  |  |
| A3520 |  | Colocación de roca en uña |  | 3d | 2025-09-14 | 2025-09-16 | A3460, A7962 SS | 12d | 0d | Excavator [16 h]; HH [16 h]; Roca [568.13 m3] | 1,120 |
| A3530 |  | Colocación de roca en talud |  | 2d | 2025-09-17 | 2025-09-18 | A3520, A3500, A3490 | 12d | 0d | Excavator [8 h]; HH [8 h]; Roca [454.54 m3] | 560 |
|  | 5 | **Transporte** |  |  | 2025-09-10 | 2025-09-18 |  |  |  |  |  |
| A6890 |  | Transporte de material orgánico (a dmo) |  | 1d | 2025-09-10 | 2025-09-10 | A3430 SS, A6860 SS | 20d | 0d | HH [8 h] |  |
| A6900 |  | Transporte de material excedente |  | 4d | 2025-09-10 | 2025-09-13 | A3440 SS, A6890 SS | 20d | 2d | HH [16 h] |  |
| A6910 |  | Transporte de material de prestamo |  | 1d | 2025-09-12 | 2025-09-12 | A3470 SS, A6900 SS | 18d | 2d | HH [8 h] |  |
| A6920 |  | Transporte de roca |  | 5d | 2025-09-14 | 2025-09-18 | A3520 SS, A6910 SS | 16d | 0d | HH [8 h] |  |
| A6940 |  | Transporte de material seleccionado para zanja |  | 1d | 2025-09-14 | 2025-09-14 | A3510 SS, A6920 SS | 16d | 4d | HH [8 h] |  |
|  | 27 | **I-01-PT** |  |  | 2025-06-01 | 2025-07-03 |  |  |  |  |  |
| A7780 |  | Inicio I-01-PT-132+360.07 - Entrega de terreno liberado | milestone | 0d | 2025-06-01 | 2025-06-01 | A5370 FS+31d | 45d | 0d |  |  |
| A7790 |  | Fin I-01-PT-132+360.07 - Entrega de terreno liberado | milestone | 0d | 2025-07-03 | 2025-07-03 | A4710 FF, A7200 FF, A7220 FF | 89d | 80d |  |  |
|  | 1 | **DIQUE** |  |  | 2025-06-01 | 2025-07-03 |  |  |  |  |  |
|  | 1 | **Excavaciones** |  |  | 2025-06-01 | 2025-06-20 |  |  |  |  |  |
| A4620 |  | Desbroce |  | 1d | 2025-06-01 | 2025-06-01 | A7780 SS | 45d | 0d | Excavator [8 h]; HH [8 h] | 560 |
| A4630 |  | Excavación de cimentación |  | 12d | 2025-06-01 | 2025-06-12 | A4620 SS | 45d | 0d | Excavator [96 h]; HH [96 h] | 6,720 |
| A4640 |  | Perfilado y conformación de plataforma de fundación |  | 7d | 2025-06-06 | 2025-06-12 | A4630 SS+5d | 47d | 0d | HH [56 h] |  |
| A4650 |  | Excavación de uña |  | 8d | 2025-06-13 | 2025-06-20 | A4630, A4640 | 47d | 2d | Excavator [64 h]; HH [64 h] | 4,480 |

| ID | WBS | Activity | Type | Duration | Start | Finish | Predecessors | Total float | Free float | Resources | Cost |
| --- | --- | --- | --- | --- | --- | --- | --- | --- | --- | --- | --- |
|  | 2 | **Rellenos** |  |  | 2025-06-02 | 2025-06-06 |  |  |  |  |  |
| A4660 |  | Relleno con material granular (incluye extracción de material, zarandeo y |  | 2d | 2025-06-02 | 2025-06-03 | A4630 SS+1d | 52d | 0d | HH [16 h]; MONEDA [788.38] | 788.38 |
| A4670 |  | Relleno mejorado con cemento |  | 3d | 2025-06-04 | 2025-06-06 | A4660 | 52d | 0d | HH [24 h]; Relleno mejorado con Cemento [209] |  |
|  | 3 | **Geotextil** |  |  | 2025-06-04 | 2025-06-15 |  |  |  |  |  |
| A4690 |  | Zanja de anclaje |  | 3d | 2025-06-04 | 2025-06-06 | A4660 | 52d | 0d | HH [24 h] |  |
| A4680 |  | Instalación de geotextil 400 gr/m2 |  | 9d | 2025-06-07 | 2025-06-15 | A4690, A4670 | 52d | 7d | HH [72 h]; Geotextil [4278.19] |  |
|  | 4 | **Colocacion de Roca** |  |  | 2025-06-09 | 2025-07-03 |  |  |  |  |  |
| A4700 |  | Colocación de roca en uña |  | 14d | 2025-06-09 | 2025-06-22 | A4630 SS+8d, A7961 SS | 45d | 0d | Excavator [96 h]; HH [96 h]; Roca [3268.22 m3] | 6,720 |
| A4710 |  | Colocación de roca en talud |  | 11d | 2025-06-23 | 2025-07-03 | A4700, A4680, A4650, A8210 | 45d | 0d | Excavator [64 h]; HH [64 h]; Roca [1769.98 m3] | 4,480 |
|  | 5 | **Transporte** |  |  | 2025-06-01 | 2025-07-03 |  |  |  |  |  |
| A7190 |  | Transporte de material orgánico (a dmo) |  | 1d | 2025-06-01 | 2025-06-01 | A4620 SS | 97d | 8d | HH [8 h] |  |
| A7200 |  | Transporte de material excedente |  | 20d | 2025-06-01 | 2025-06-20 | A4630 SS | 102d | 13d | HH [160 h] |  |
| A7210 |  | Transporte de material de prestamo (afirmado) |  | 2d | 2025-06-02 | 2025-06-03 | A4660 SS | 92d | 0d | HH [16 h] |  |
| A7240 |  | Transporte de material seleccionado para zanja |  | 2d | 2025-06-04 | 2025-06-05 | A4690 SS, A7210 | 92d | 3d | HH [16 h] |  |
| A7220 |  | Transporte de roca |  | 25d | 2025-06-09 | 2025-07-03 | A4700 SS, A7240, A7190 SS | 89d | 0d | HH [160 h] |  |
|  | 15 | **D-03-DI** |  |  | 2025-07-04 | 2025-07-28 |  |  |  |  |  |
| A7600 |  | Inicio D-03-DI-108+238.01 - Entrega de terreno liberado | milestone | 0d | 2025-07-04 | 2025-07-04 | A4710 | 45d | 0d |  |  |
| A7610 |  | Fin D-03-DI-108+238.01 - Entrega de terreno liberado | milestone | 0d | 2025-07-28 | 2025-07-28 | A3140 FF, A6700 FF, A6680 FF | 69d | 55d |  |  |
|  | 1 | **DIQUE** |  |  | 2025-07-04 | 2025-07-28 |  |  |  |  |  |
|  | 1 | **Excavaciones** |  |  | 2025-07-04 | 2025-07-13 |  |  |  |  |  |
| A3020 |  | Desbroce |  | 1d | 2025-07-04 | 2025-07-04 | A7600 SS | 45d | 0d | Excavator [8 h]; HH [8 h] | 560 |
| A3030 |  | Excavación de cimentación |  | 4d | 2025-07-04 | 2025-07-07 | A3020 SS | 45d | 0d | Excavator [32 h]; HH [32 h] | 2,240 |
| A3040 |  | Perfilado y conformación de plataforma de fundación |  | 2d | 2025-07-05 | 2025-07-06 | A3030 SS+1d | 48d | 3d | HH [16 h] |  |
| A3060 |  | Excavación localizada - sobreexcavación |  | 2d | 2025-07-08 | 2025-07-09 | A3030 | 45d | 0d | HH [16 h] |  |
| A3050 |  | Excavacion de uña |  | 4d | 2025-07-10 | 2025-07-13 | A3030, A3040, A3060 | 45d | 0d | Excavator [32 h]; HH [32 h] | 2,240 |

| ID | WBS | Activity | Type | Duration | Start | Finish | Predecessors | Total float | Free float | Resources | Cost |
| --- | --- | --- | --- | --- | --- | --- | --- | --- | --- | --- | --- |
|  | 2 | **Rellenos** |  |  | 2025-07-08 | 2025-07-10 |  |  |  |  |  |
| A3070 |  | Relleno con material granular (incluye extracción de material, zarandeo y / combinación de material) |  | 1d | 2025-07-08 | 2025-07-08 | A3030 | 49d | 0d | HH [8 h]; MONEDA [593.25] | 593.25 |
| A3080 |  | Perfilado de talud del dique |  | 1d | 2025-07-08 | 2025-07-08 | A3070 SS | 49d | 0d | HH [8 h] |  |
| A3090 |  | Relleno con material seleccionado (incluye extracción de material, / zarandeo y combinación de material) en sobreex |  | 1d | 2025-07-09 | 2025-07-09 | A3070, A3080 | 49d | 0d | HH [8 h]; Cerco [230.8] |  |
| A3100 |  | Relleno mejorado con cemento |  | 1d | 2025-07-10 | 2025-07-10 | A3090 | 49d | 0d | HH [8 h]; Relleno mejorado con Cemento [154.25] |  |
|  | 3 | **Geotextil** |  |  | 2025-07-11 | 2025-07-16 |  |  |  |  |  |
| A3120 |  | Zanja de anclaje |  | 1d | 2025-07-11 | 2025-07-11 | A3100 | 49d | 0d | HH [8 h] |  |
| A3110 |  | Instalación de geotextil 400 gr/m2 |  | 5d | 2025-07-12 | 2025-07-16 | A3120 | 49d | 4d | HH [40 h]; Geotextil [2914.19] |  |
|  | 4 | **Colocacion de Roca** |  |  | 2025-07-14 | 2025-07-28 |  |  |  |  |  |
| A3130 |  | Colocación de roca en uña |  | 7d | 2025-07-14 | 2025-07-20 | A3030, A3050, A7962 SS | 45d | 0d | Excavator [56 h]; HH [56 h]; Roca [1825.14 m3] | 3,920 |
| A3140 |  | Colocación de roca en talud |  | 8d | 2025-07-21 | 2025-07-28 | A3130, A3050, A3110, A8250 | 45d | 0d | Excavator [64 h]; HH [64 h]; Roca [1684.61 m3] | 4,480 |
|  | 5 | **Transporte** |  |  | 2025-07-04 | 2025-07-28 |  |  |  |  |  |
| A6650 |  | Transporte de material orgánico (a dmo) |  | 1d | 2025-07-04 | 2025-07-04 | A3020 SS | 79d | 0d | HH [8 h] |  |
| A6660 |  | Transporte de material excedente |  | 10d | 2025-07-04 | 2025-07-13 | A3030 SS, A6650 SS | 79d | 10d | HH [64 h] |  |
| A6670 |  | Transporte de material de prestamo (afirmado) |  | 1d | 2025-07-08 | 2025-07-08 | A3070 SS | 87d | 0d | HH [8 h] |  |
| A6690 |  | Transporte de material de préstamo cantera de rio (cuerpo de terraplén) |  | 1d | 2025-07-09 | 2025-07-09 | A3090 SS, A6670 | 87d | 1d | HH [8 h] |  |
| A6700 |  | Transporte de material seleccionado para zanja |  | 1d | 2025-07-11 | 2025-07-11 | A3120 SS, A6690 | 86d | 17d | HH [8 h] |  |
| A6680 |  | Transporte de roca |  | 15d | 2025-07-14 | 2025-07-28 | A3130 SS, A6660 SS | 69d | 0d | HH [128 h] |  |
|  | 20 | **I-06-1-CM- Muro** |  |  | 2025-07-29 | 2025-08-15 |  |  |  |  |  |
| A7620 |  | Inicio I-06-1-CM-111+198.46 - Entrega de terreno liberado | milestone | 0d | 2025-07-29 | 2025-07-29 | A3140 | 45d | 0d |  |  |
| A7630 |  | Fin I-06-1-CM-111+198.46 - Entrega de terreno liberado | milestone | 0d | 2025-08-15 | 2025-08-15 | A4900 FF, A6740 FF, A4940 FF | 45d |  |  |  |
|  | 1 | **DIQUE** |  |  | 2025-07-29 | 2025-08-09 |  |  |  |  |  |
|  | 1 | **Excavaciones** |  |  | 2025-07-29 | 2025-08-04 |  |  |  |  |  |
| A3280 |  | Desbroce |  | 2d | 2025-07-29 | 2025-07-30 | A7620 SS | 45d | 0d | Excavator [16 h]; HH [16 h] | 1,120 |
| A3290 |  | Excavación de cimentación |  | 5d | 2025-07-31 | 2025-08-04 | A3280 | 46d | 0d | Excavator [40 h]; HH [40 h] | 2,800 |

| ID | WBS | Activity | Duration | Start | Finish | Predecessors | Total float | Free float | Resources | Cost |
| --- | --- | --- | --- | --- | --- | --- | --- | --- | --- | --- |
|  | 4 | **Colocacion de Roca** |  | 2025-08-02 | 2025-08-09 |  |  |  |  |  |
| A5010 |  | Colocacion de roca en uña | 8d | 2025-08-02 | 2025-08-09 | A3290 SS+2d, A7962 SS | 46d | 0d | Excavator [64 h]; HH [64 h]; Roca [1755.73 m3] | 4,480 |
|  | 5 | **Transporte** |  | 2025-07-29 | 2025-08-09 |  |  |  |  |  |
| A6710 |  | Transporte de material orgánico (a dmo) | 1d | 2025-07-29 | 2025-07-29 | A3280 SS | 54d | 1d | HH [8 h] |  |
| A6720 |  | Transporte de material excedente | 5d | 2025-07-31 | 2025-08-04 | A3290 SS, A6710 | 53d | 2d | HH [32 h] |  |
| A6740 |  | Transporte de roca | 8d | 2025-08-02 | 2025-08-09 | A5010 SS, A6720 SS | 51d | 6d | HH [48 h] |  |
|  | 3 | **MURO** |  | 2025-07-31 | 2025-08-15 |  |  |  |  |  |
| A4940 |  | Encofrado y desencofrado cara oculta | 16d | 2025-07-31 | 2025-08-15 | A3280 SS+2d | 45d | 0d | HH [120 h]; MADERA TORNILLO [3967 und] |  |
| A4900 |  | Concreto de nivelacion (f'c=100 kg/cm2) | 12d | 2025-08-03 | 2025-08-14 | A5010 SS+1d, A4940 SS | 46d | 1d | HH [96 h]; CONCRETO PREMEZCLADO F'C=100 kg/cm2 CON CEMENTO T-I [216] |  |
